# Programac_obra.mpp

Schedule from MS Project, 2007-05-01 to 2007-08-28, status date 2007-03-27, costs in S/..
BLENDERCOM tel.(01)98066409

## Calendars

- Estándar: Mon-Sat 08:00-14:00, 15:00-17:00; Sun off. Exceptions (off unless hours are given): 2007-05-06 08:00-14:00, 15:00-17:00, 2007-05-13 08:00-14:00, 15:00-17:00, 2007-05-20 08:00-14:00, 15:00-17:00, 2007-05-27 08:00-14:00, 15:00-17:00, 2007-06-03 08:00-14:00, 15:00-17:00, 2007-06-10 08:00-14:00, 15:00-17:00, 2007-06-17 08:00-14:00, 15:00-17:00, 2007-06-24 08:00-14:00, 15:00-17:00, 2007-07-01 08:00-14:00, 15:00-17:00, 2007-07-08 08:00-14:00, 15:00-17:00, 2007-07-15 08:00-14:00, 15:00-17:00, 2007-07-22 08:00-14:00, 15:00-17:00, 2007-07-29 08:00-14:00, 15:00-17:00, 2007-08-05 08:00-14:00, 15:00-17:00, 2007-08-12 08:00-14:00, 15:00-17:00, 2007-08-19 08:00-14:00, 15:00-17:00, 2007-08-26 to 2007-08-27 08:00-14:00, 15:00-17:00.

## Resources

| Resource | Group | Unit | Rate |
| --- | --- | --- | --- |
| ALAMBRE NEGRO RECOCIDO # 16 | 020007 | kg | 2.35 |
| ALAMBRE NEGRO RECOCIDO # 8 | 020008 | kg | 2.35 |
| ALAMBRE GALVANIZADO # 16 | 020031 | kg | 2.35 |
| CLAVOS PARA MADERA SIN CABEZA | 021080 | kg | 3.68 |
| CLAVOS CON CABEZA PROMEDIO | 021090 | kg | 2.35 |
| TIRAFON 11/2"x1/8" | 021095 | und | 0.44 |
| TIRAFON 3"x1/8" | 021096 | und | 0.6 |
| CLAVO PARA CEMENTO DE 1" | 021097 | kg | 0.6 |
| CLAVOS CON CABEZA PROMEDIO | 021099 | KG. | 2.35 |
| TORNILLO AVELLANADO | 025139 | und | 0.6 |
| PERNOS CON TUERCAS 5/8" X 10" | 025143 | pza | 0.75 |
| ARANDELAS DE 5/8" | 025160 | pza | 2.8 |
| TORNILLO SPAX | 025170 | cto | 2.2 |
| TORNILLO DE FIJACION 2" C/TARUGOS DE PLASTICO | 025174 | und | 0.21 |
| TIRAFONES 5" C/ARANDELA PLASTICA P/TEJA | 025175 | und | 0.7 |
| PERNO 1/2"x3" CON TUERCA | 025176 | und | 0.75 |
| PERNO CON TUERCA 7"X3/8" | 025178 | und | 1.22 |
| ACERO CORRUGADO FY=4200 Kg/cm2 GRADO 60 | 030300 | kg | 2.14 |
| ARENA FINA | 040000 | m3 | 16.1 |
| ARENA GRUESA | 040007 | m3 | 16.1 |
| TIERRA DE CHACRA | 041112 | m3 | 5 |
| AGUA | 041201 | m3 | 6 |
| PIEDRA CHANCADA | 050033 | m3 | 39.85 |
| MATERIAL DE AFIRMADO | 050105 | m3 | 17 |
| PIEDRA MEDIANA | 050201 | m3 | 25 |
| PIEDRA GRANDE | 050210 | m3 | 25 |
| CABLE DE COBRE DESNUDO TIPO SUAVE 10MM2 | 060204 | mL | 1.59 |
| CABLE DE COBRE DESNUDO TIPO SUAVE 35mm2 | 060207 | mL | 6.45 |
| CABLE DE COBRE DESNUDO 50 mm2 | 060208 | mL | 8.92 |
| CONECTOR BR BARRA DE 5/8"-3/4" | 065001 | und | 7.8 |
| BARRA DE COBRE DE 5/8" x 2.40 m | 067101 | und | 76 |
| BARRA DE COBRE DE 3/4" x 2.40 m | 067102 | und | 76 |
| CABLE TW 2.5 mm2 | 070101 | mL | 0.58 |
| CABLE TW 4 mm2 | 070102 | mL | 0.9 |
| CABLE TW 6 mm2 | 070103 | mL | 1.28 |
| CABLE TW 10 mm2 | 070104 | mL | 1.98 |
| CABLE THW 4mm2 | 070302 | mL | 0.97 |
| CABLE THW 10mm2 | 070304 | mL | 2.12 |
| CABLE THW 25mm2 | 070306 | mL | 5.1 |
| CABLE THW 95mm2 | 070311 | mL | 19.92 |
| INODORO TIPO C-4 (INC. ACCESORIOS) | 100102 | und | 190 |
| LAVADERO TIPO B-1 (*) | 100301 | und | 182.4 |
| LAVADERO TIPO B-9b (*) | 100304 | und | 220 |
| LAVADERO TIPO S-7A | 100311 | und | 165 |
| LAVATORIO TIPO A-3 (INC. GRIF. Y ACCESOR.) | 100405 | und | 190 |
| GRIFO DE RIEGO DE 1/2" | 102002 | und | 8.9 |
| GRIFO DE BRONCE DE 1/2" | 102011 | und | 8.5 |
| PAPELERA CON EJE DE 15 X 15 BLANCA | 105001 | und | 7.4 |
| JABONERA DE LOSA COLOR BLANCO | 105011 | und | 7.4 |
| GANCHO DE SOBREPONER | 105021 | und | 4.2 |
| DUCHA DE 2 LLAVES (AGUA FRIA Y CALIENTE) | 105043 | pza | 92.5 |
| DUCHA TELEFONO | 105044 | pza | 42.9 |
| DISPENSADOR DE JABON LIQUIDO/YODO | 106201 | und | 35.3 |
| THERMA CAP=120 LT INC. ACCESORIO | 106301 | und | 780.75 |
| DOSIS QUIMICA THOR-GEL | 111001 | und | 59 |
| TAPA DE CONCRETO PARA POZO DE TIERRA | 111004 | und | 18 |
| BENTONITA | 111005 | pqt | 66.61 |
| CAPTOR THOR MOD. T-100 r=90m. | 112301 | und | 3880 |
| PLACA DE ALUMINIO ANODIZADO DE 1 HUECO | 120301 | und | 5.2 |
| PLACA DE ALUMINIO ANODIZADO DE 2 HUECOS | 120302 | und | 5.2 |
| PLACA DE ACERO INOXIDABLE DE 2 HUECOS | 120315 | und | 5.2 |
| DADO INTERRUPTOR | 120401 | und | 6.5 |
| DADO TOMACORRIENTE BIPOLAR 15A / 220V | 120403 | und | 6.8 |
| DADO DE CONMUTACION | 120431 | und | 19.72 |
| DADO TOMACORRIENTE C/TIERRA 15A / 220V | 120435 | und | 11.15 |
| CAJA DE FoGo DE 100x55x50 | 120800 | und | 0.85 |
| CAJA DE FoGo DE 100x100x55 | 120802 | und | 6.61 |
| CAJA DE FoGo DE 120x120x55 | 120805 | und | 10.5 |
| CAJA DE FoGo DE 250x250x120 | 120825 | und | 26 |
| CAJA DE FoGo DE 300x300x150 | 120833 | und | 39.25 |
| CAJA DE FoGo DE 400x400x150 | 120841 | und | 45 |
| CAJA DE FoGo DE 500 x500x150 mm | 120876 | und | 52 |
| CAJA OCTOGONAL DE FoGo 100x50 | 121001 | und | 0.76 |
| CAJA OCTOGONAL DE FoGo 100x55 | 121002 | und | 0.76 |
| ARTEF. TIPO D (ADOSADO) CUAD. 2´X2´ DIF.REJ.ALUM 2x36W AFP | 122008 | und | 187.57 |
| ARTEF. TIPO G1 DIF. TIPO GLOBO VID. 1X11W | 122019 | und | 24.9 |
| ARTEF. TIPO A2 (ADOSADO C/DIFUSOR PRISMATICO) | 122057 | und | 121.45 |
| ARTEF. TIPO A4 (ADOSADO C/DIFUSOR PRISMATICO) | 122058 | und | 260.25 |
| ARTEF. TIPO A6 (ADOSADO C/DIFUSOR PRISMATICO) | 122060 | und | 64 |
| ARTEF. BRAQUETE DE ALUMINIO FLUORESECNTE COMPACTO | 122114 | und | 97.8 |
| ARTEF. LUZ DE GUARDIA P/EMPOTRAR DIF. REJILLA CON LAMPAR | 122401 | und | 69.4 |
| LUZ DE EMERGENCIA | 122403 | und | 145.8 |
| TOMACORRIENTE DOBLE A PRUEBA DE AGUA | 123802 | und | 42.2 |
| INTERRUPTOR TERMOMAGNETICO 2X15A | 124004 | und | 34.7 |
| INTERRUPTOR TERMOMAGNETICO 2X20A | 124005 | und | 34.7 |
| INTERRUPTOR TERMOMAGNETICO 2X30A | 124006 | und | 34.7 |
| INTERRUPTOR TERMOMAGNETICO 3X20A | 124015 | und | 80 |
| INTERRUPTOR TERMOMAGNETICO 3X30A | 124016 | und | 118 |
| INTERRUPTOR TERMOMAGNETICO 3X40A | 124017 | und | 118 |
| INTERRUPTOR TERMOMAGNETICO 3X100A | 124020 | und | 149.21 |
| INTERRUPTOR TERMOMAGNETICO 3x90A | 124030 | und | 149.21 |
| INTERRUPTOR TERMOMAGNETICO 3x75 A | 124033 | und | 149.21 |
| INTERRUPTOR TERMOMAGNETICO 3x175A | 124034 | und | 180.44 |
| TABLERO GENERAL (SEGUN ESPECIFICACIONES) | 124103 | und | 241.52 |
| TABLERO TD-2 | 124303 | und | 171.76 |
| TABLERO TD-3 | 124304 | und | 171.76 |
| TABLERO TD-4 | 124305 | und | 92 |
| TABLERO STC | 124315 | und | 92 |
| TABLERO TQ | 124317 | und | 92 |
| TABLERO TS-1 | 124318 | und | 173.25 |
| TABLERO TE-1 | 124319 | und | 92 |
| TABLERO TD-1 | 124351 | und | 171.76 |
| ARTEFACTO TIPO ANTORCHA | 124401 | und | 313.2 |
| ASFALTO RC-250 | 130006 | gln | 8.5 |
| VINILICO DE ALTO TRANSITO 3.2 mm | 160023 | m2 | 35.27 |
| PEGAMENTO ASFALTICO PARA PISOS | 161301 | gln | 22 |
| LADRILLO KK 18 HUECOS HECHO A MAQUINA 9X13X23 | 170001 | und | 0.39 |
| LADRILLO PARA TECHO 15X30X30cm 8 HUECOS | 170103 | und | 0.84 |
| CABLE DE ENERGIA NYY 1 KV 3-1X50mm2 | 190607 | mL | 38.27 |
| CEMENTO PORTLAND TIPO I (42.5 kg) | 210000 | bol | 16.8 |
| LOSETA CERAM.SERIE AMERICA SATINADO 30 X30 O SIMILAR | 240611 | m2 | 20.8 |
| LOSETA CERAMICA DE ALTO TRANSITO .30x.30 | 240720 | m2 | 25.9 |
| CONTRAZOCALO CERAMICO .10x.30 | 240721 | mL | 8.8 |
| BISAGRA DE ACERO REVESTIDA EN PLOMO DE 4"x4" | 260834 | und | 6.5 |
| BISAGRA CANGREJO DE 3" | 260882 | und | 1.2 |
| BISAGRA VAI VEN DE 4" | 260883 | und | 7.5 |
| BISAGRA ALUMINIZADA DE 2"x2" | 260891 | und | 0.8 |
| BISAGRA ALUMINIZADA DE 4"x4" | 260892 | und | 1.45 |
| TIRADORES DE METAL PLASTIFICADO DE 4" | 262004 | und | 6.2 |
| CERRADURA TIPO C | 262703 | und | 16.9 |
| GARRUCHAS DE 3" | 267857 | und | 22 |
| CORREDERA PARA CAJONES | 269201 | jgo | 4.8 |
| BISAGRA DE FIERRO DE 5" | 269401 | und | 5 |
| CEMENTO BLANCO BOLSA 50 kg | 300001 | bol | 59.47 |
| SULFATO DE BARIO ( BARITINA ) | 300198 | kg | 1.5 |
| YESO BOLSA DE 20 Kg | 300201 | bol | 7.56 |
| LAVADERO TIPO B-42 (INC. GRIFERIA Y ACCESORIOS) | 300323 | und | 285 |
| LAVADERO TIPO B-102 (INC. GRIFERIA Y ACCESORIOS) | 300324 | und | 250 |
| LAVADERO TIPO B-48 (INC. GRIFERIA Y ACCESORIOS) | 300325 | und | 310 |
| MALLA EXPANDED METAL | 300406 | m2 | 4 |
| WAYPE | 300606 | kg | 2 |
| CORDEL | 300701 | mL | 0.1 |
| IMPERMEABILIZANTE | 301114 | kg | 28.5 |
| PORCELANA | 301516 | kg | 2.52 |
| SELLADOR DE FRAGUA | 301530 | gln | 12.67 |
| TECKNOPOR DE 1" | 302206 | pln | 14.8 |
| TECKNOPOR DE 2" | 302207 | pln | 20 |
| AGUA | 302901 | M3. | 6 |
| HIPOCLORITO DE CALCIO AL 70% | 302903 | kg | 6.6 |
| LIJA PARA MADERA | 302910 | hja | 1 |
| LIJA PARA FIERRO | 302911 | hja | 1.27 |
| CORTINA DE LINO PLASTIFICADO | 302913 | m2 | 43.7 |
| SEÑAL INDICATIVA C/ACRILICO Y MARCO MAD.ADOSADO PARED | 302915 | und | 100 |
| SEÑAL ORIENTATIVA ACRILICO ADOSADA | 302918 | und | 25 |
| LETRERO LOGOTIPO PINTADO EN MURO | 302936 | und | 150 |
| VIDRIO EMPLOMADO | 303006 | und | 69.8 |
| VIDRIO TRIPLE E=6mm | 303204 | p2 | 2.62 |
| ESPEJO CRISTAL 6MM | 303232 | p2 | 4.6 |
| LAMINA PLASTICO e=0.07mm (1.22 x 2.44 m.) | 303711 | pln | 47 |
| CERRADURA TIPO A | 303841 | und | 25.9 |
| CERRADURA TIPO B | 303842 | und | 25.9 |
| CERRADURA TIPO D | 303844 | und | 26.9 |
| CERRADURA TIPO E | 303845 | und | 16.9 |
| CERRADURA TIPO F | 303846 | und | 15.5 |
| BRAZO HIDRAULICO TIPO G | 303847 | jgo | 100.8 |
| PICAPORTE TIPO J | 303850 | jgo | 6.6 |
| CERRADURA TIPO L | 303852 | und | 42 |
| TOPE DE PUERTA TIPO K | 303859 | und | 6.6 |
| CINTA TAPACANTO 0.45mm.(I/Inst.) | 303920 | mL | 0.12 |
| AGLOMERADO MDF E=5.5mm. (.80m. x 2.60m.) | 304210 | pln | 56 |
| AGLOM. C/ENCH. MELAMINICO 2 LADOS E=6mm. (2.15m.x2.44m.) | 304216 | pln | 135 |
| AGLOM. C/ENCH. MELAMINICO 2 LADOS E=16mm.2.15m.x2.44m.) | 304218 | pln | 184.2 |
| AGLOM. C/ENCH. MELAMINICO 2 LADOS E=19mm. (2.15m.x2.44m.) | 304221 | pln | 193.28 |
| AGLOM. POSTFORMADO C/ENCH. FORMICA E=19mm. (Resist.a la H.) | 304252 | mL | 74 |
| AGLOM. POSTFORMADO C/ENCHAPE FORMICA e=15mm | 304261 | mL | 62 |
| SILICONA | 304632 | und | 7.8 |
| PEGAMENTO PARA TUBERIA PVC | 304640 | gln | 116.79 |
| PEGAMENTO PARA TUBERIA CPVC DE 1/4 | 304641 | und | 65 |
| COLA SINTETICA | 304661 | gln | 15 |
| PEGAMENTO PARA FORMICA (1/4 gln.) | 304662 | und | 11.2 |
| SOLDADURA CELLOCORD TIPO 6011 | 304716 | kg | 8.05 |
| CINTA AISLANTE | 304810 | rll | 2 |
| CINTA TEFLON | 304820 | rll | 1.5 |
| CINTA SEÑALIZADORA | 304842 | mL | 0.5 |
| OCRE | 305200 | kg | 15 |
| PLANCHA DE PLOMO (1/16" x 1.20 x 2.50m. ) | 305402 | pln | 58 |
| DUCTO DE CONCRETO DE 2 VIAS | 310201 | pza | 19.74 |
| TRANSPORTE DE EQUIPO Y HERRAMIENTAS | 320102 | glb | 1500 |
| HORMIGON | 380000 | m3 | 16.1 |
| MARMOLINA (BOLSA DE 40 KG) | 400409 | bol | 36 |
| GRANALLA (BOLSA DE 40KG) | 400410 | bol | 12.1 |
| MADERA PARA REGLAS (CEDRO) | 430023 | p2 | 5 |
| MADERA TORNILLO | 430103 | p2 | 2.1 |
| CAJA DE MADERA DE 200x100x100 mm | 431001 | und | 5 |
| CAJA DE MADERA DE 300x300x120 mm | 431014 | und | 12 |
| MADERA CEDRO | 431386 | p2 | 3.8 |
| ZOCALO DE MADERA CEDRO 4"x3/4" | 431387 | mL | 4.42 |
| RODON DE MADERA CEDRO 1" | 431388 | mL | 1.85 |
| TARUGO 1 1/2" x 2" | 435401 | und | 0.3 |
| MADERA TORNILLO CEPILLADA | 440016 | p2 | 2.5 |
| TRIPLAY DE 4´x 8´x 4mm. | 440302 | pln | 16 |
| OPERADOR DE EQUIPO LIVIANO | 470022 | H.H. | 9.19 |
| OPERADOR DE EQUIPO PESADO | 470023 | H.H | 9.19 |
| CAPATAZ | 470101 | H.H | 11.2 |
| OPERARIO | 470102 | H.H | 10.16 |
| OFICIAL | 470103 | H.H | 9.19 |
| PEON | 470104 | H.H | 8.27 |
| TOPOGRAFO | 470106 | H.H | 10.16 |
| MEZCLADORA DE CONCRETO TOLVA 9P3 | 480002 | HM. | 22.39 |
| MEZCLADORA DE CONCRETO TOLVA 11P3 | 480003 | HM. | 22.39 |
| WINCHE ELECTRICO 3.6 HP DE DOS BALDES | 480181 | HM. | 8.2 |
| MEZCLADORA DE CONCRETO TAMBOR 11 p3 22 HP | 480185 | HM. | 22.39 |
| VOLQUETE 6X4 330 HP 10M3 | 481004 | HM. | 181.15 |
| PULIDORA DE TERRAZO; MARMOL Y OTROS | 483002 | HM. | 5 |
| CEPILLADORA ELECTRICA | 484001 | HM. | 6 |
| EQUIPO DE CORTE Y SOLDEO | 486001 | HM. | 6 |
| EQUIPO DE SOLDEO | 486002 | HM. | 6 |
| EQUIPO DE CORTE | 486003 | HM. | 3 |
| ANDAMIO METALICO | 488004 | HM. | 2 |
| SIERRA CIRCULAR | 488101 | HM. | 5.5 |
| VIBRADORA DE CONCRETO 4 HP 2.40" | 490003 | HM. | 5.8 |
| CARGADOR FRONTAL S/LLANTAS 125-155 HP | 491004 | HM. | 141.5 |
| MEZCLADORA DE CONCRETO TAMBOR 18 HP 11 p3 | 491007 | HM. | 22.39 |
| COMPACTADOR VIBRATORIO TIPO PLANCHA 4HP | 492001 | HM. | 5.8 |
| COMPRESORA NEUMATICA | 493001 | H-M | 83.88 |
| MARTILLO NEUMATICO | 493021 | H-M | 11.75 |
| TEODOLITO | 495102 | HM. | 8.8 |
| NIVEL | 495103 | HM. | 6.9 |
| JALON | 495104 | HM. | 0.15 |
| MIRA | 495105 | HM. | 0.25 |
| EQUIPO DE BOMBEO | 496011 | HM. | 12 |
| MEGOMETRO | 496201 | HM. | 3.75 |
| TRACTORES SOBRE ORUGAS 140-160 HP | 496904 | HM. | 146.8 |
| WINCHE DE DOS BALDES (350 KG)ME 3.6 HP | 497001 | HM. | 8.2 |
| TAPA DE FIERRO DE 0.70x0.70 M (INST. SANITARIA) | 500202 | und | 35 |
| ANGULO DE FIERRO NEGRO DE 1 1/2" X 1 1/2" X 1/8" X 6m | 510118 | pza | 18.95 |
| ANGULAR DE 1"x1"x3/16"x6M. | 510121 | pza | 22.92 |
| ANGULAR DE FIERRO NEGRO DE 1"x1"x1/8" | 510206 | pza | 16.2 |
| PLATINA DE FIERRO NEGRO DE 1 1/2 x 1/4" x6m | 510537 | pza | 23.94 |
| PLATINA DE FIERRO 1/4"x6" | 510546 | mL | 2.52 |
| PLATINA DE FIERRO DE 3/4"x1/8"x6m | 510547 | pza | 5.8 |
| PLATINA DE FIERRO DE 1/2" | 510548 | mL | 0.8 |
| PLATINA DE ACERO 1/4" X 1 1/2" X 6 m | 511307 | pza | 23.94 |
| PLATINA DE F.N. 1/ 4" X 2"X 6 m | 511334 | pza | 30.41 |
| SOPORTE P/TENSADO TIPO CARRETE FoGo | 518217 | und | 21.98 |
| TUBO REDONDO D=1" ALUMINIO | 520845 | pza | 14.6 |
| TUBO DE ALUMINIO (DIFUSA 00-5568-12) | 520852 | mL | 12 |
| PATINES DE 4 RODAJES | 521002 | und | 6.2 |
| PLATINA DE ALUMINIO 1 X 1/8" | 521211 | mL | 1.88 |
| "T" DE ALUMINIO DE 1"x1"x 1/8" | 521212 | mL | 1.88 |
| CANOPLA DE ALUMINIO DE 1" | 523108 | pza | 6.8 |
| CANOPLA DE ALUMINIO (DIFUSA 00-21042) | 523109 | pza | 15 |
| SISTEMA PIVOT ALUMINIO PARA VENTANAS INC. COLOCACION | 523803 | mL | 65 |
| SISTEMA FIJO ALUMINIO PARA VENTANAS INC. COLOCACION | 523804 | mL | 55 |
| SISTEMA CORREDIZO ALUMINIO PARA VENTANAS INC. COLOCACION | 523805 | mL | 135 |
| SISTEMA VITROVEN PARA VENTANAS INC. COLOCACION | 523806 | mL | 68 |
| RIEL DE ALUMINIO 1 1/4" x 1 1/4" | 524002 | pza | 6.47 |
| IMPRIMANTE | 540103 | gln | 4.63 |
| PINTURA ESMALTE | 540281 | gln | 26.89 |
| PINTURA ANTICORROSIVA | 540282 | gln | 28 |
| PINTURA LATEX ECONOMICO | 540300 | gln | 12.6 |
| PINTURA EPOXICA | 540801 | gln | 28 |
| AGUARRAS | 544301 | gln | 8.4 |
| BARNIZ MARINO | 545001 | gln | 24.8 |
| THINNER ACRILICO | 549101 | gln | 10.04 |
| LACA SELLADORA P/MADERA | 549203 | gln | 23.45 |
| LACA ACRILICA | 549204 | gln | 28.4 |
| PINTURA LATEX SINTETICO | 549301 | gln | 16.86 |
| PINTURA LATEX POLIVINILICO | 549401 | gln | 27.88 |
| PINTURA LATEX ACRILICO | 549402 | gln | 31.27 |
| PRESERVANTE PARA MADERA | 549601 | gln | 23.53 |
| BARNIZ SELLADOR PARA MADERA | 549701 | gln | 20.8 |
| PLANCHA DE ACERO INOXIDABLE SEMI MATE 1/32" | 561135 | m2 | 70.9 |
| PLANCHA DE ACERO LAC 3/16" | 561157 | pza | 254 |
| PLANCHA DE ACERO e= 1/16" | 561161 | pza | 85.92 |
| PLANCHA GRAN ONDA 1.83 M | 590101 | pza | 28.66 |
| PERFIL 4 ETERNIT ROJO 2.44x1.10x4mm | 590102 | pza | 27.42 |
| PLANCHA TEJA ANDINA FIBROCEMENTO 1.16x .72 | 590201 | und | 27.42 |
| CUMBRERA SUPERIOR TEJA ANDINA FIBROCEMENTO | 590202 | und | 15.99 |
| CUMBRERA INFERIOR TEJA ANDINA FIBROCEMENTO | 590203 | und | 15.99 |
| TUBO DE FIERRO GALVANIZADO DE 1/2" X 6.40 m | 650103 | pza | 26 |
| TUBO DE FºGº 1" | 650144 | mL | 8.71 |
| TUBO DE FºGº 1 1/2" | 650145 | mL | 13.3 |
| MASTIL DE FoGo 2" y 3" C/ACOPLE P/PARARRAYO | 650146 | und | 190 |
| TUBO PROTECTOR DE FoGo 2"x3m C/ABRAZADERA | 650147 | und | 93.21 |
| CODO DE FIERRO GALVANIZADO DE 1/2" X 90o | 650203 | und | 1.27 |
| CODO DE FIERRO GALVANIZADO DE 1 1/2" X 90o | 650206 | und | 6.78 |
| CODO DE FIERRO GALVANIZADO DE 2 " X 90o | 650283 | und | 8.05 |
| UNION UNIVERSAL DE FIERRO GALVANIZADO DE 1/2" | 650522 | und | 3.39 |
| UNION UNIVERSAL DE FIERRO GALVANIZADO DE 1 1/2" | 650526 | und | 14.41 |
| UNION UNIVERSAL DE FIERRO GALVANIZADO DE 2" | 650527 | und | 20.34 |
| NIPLE DE FIERRO GALVANIZADO DE 1/2"x1" | 651313 | und | 1.47 |
| NIPLE DE FIERRO GALVANIZADO DE 1 1/2"X 2" | 651316 | und | 1.95 |
| NIPLE DE FIERRO GALVANIZADO DE 2"x4" | 651365 | und | 6.8 |
| BARRA DE FIERRO REDONDO LISO 1/2"x6m | 652080 | pza | 4.5 |
| TUBO DE FIERRO NEGRO 3"x 3"x 3/16" | 653131 | pza | 131.2 |
| TUBO DE FIERRO NEGRO 2"x2"x 3/16" | 653132 | pza | 62.28 |
| CANALETA GALVANIZADA DE ZINC D=6" | 654201 | ML. | 16 |
| TUBERIA DE C.S.N. ESPIGA CAMPANA DE 4" X 1M | 690101 | pza | 11.44 |
| TUBERIA PVC C-10 C/R DE 1/2" X 5 m | 720101 | pza | 7.92 |
| TUBERIA PVC C-10 C/R DE 3/4" X 5 m | 720102 | pza | 10.16 |
| TUBERIA PVC C-10 C/R DE 1" X 5 m | 720103 | pza | 12.8 |
| TUBERIA PVC C-10 C/R DE 1 1/2" X 5 m | 720105 | pza | 24.01 |
| TUBERIA PVC C-10 C/R DE 2" x 5 m | 720136 | mL | 53.9 |
| UNION PVC PARA AGUA CON ROSCA 3/4" | 720302 | pza | 1.21 |
| UNION PVC PARA AGUA CON ROSCA 1" | 720303 | pza | 1.63 |
| UNION PVC PARA AGUA CON ROSCA 1 1/2" | 720305 | pza | 4.82 |
| UNION PVC PARA AGUA CON ROSCA 2" | 720306 | pza | 13.4 |
| UNION UNIVERSAL CPVC AGUA CALIENTE 1/2" | 720344 | pza | 7.4 |
| CODO PVC AGUA CON ROSCA DE 1/2" X90o | 720601 | pza | 0.31 |
| CODO PVC AGUA CON ROSCA DE 3/4" X90o | 720602 | pza | 2.16 |
| CODO PVC AGUA CON ROSCA DE 1" X90o | 720603 | pza | 4.2 |
| CODO PVC AGUA CON ROSCA DE 1 1/2" X90o | 720605 | pza | 9.36 |
| CODO PVC AGUA CON ROSCA DE 2" X90o | 720606 | pza | 13.56 |
| CODO DE CPVC DE 1/2"x 90º | 720611 | pza | 0.76 |
| TEE PVC PARA AGUA CON ROSCA DE 1/2" | 720701 | und | 0.41 |
| TEE PVC PARA AGUA CON ROSCA DE 3/4" | 720702 | und | 2.75 |
| TEE PVC PARA AGUA CON ROSCA DE 1" | 720703 | und | 4.16 |
| TEE PVC PARA AGUA CON ROSCA DE 1 1/2" | 720705 | und | 6.5 |
| TEE PVC PARA AGUA CON ROSCA DE 2" | 720706 | und | 12.14 |
| ADAPTADOR PVC SAP 1/2" | 720801 | und | 0.85 |
| ADAPTADOR CPVC A. CALIENTE MACHO PRESION 1/2" | 720803 | pza | 1.2 |
| TUBERIA CPVC 1/2" X 5m | 722001 | und | 23 |
| CODO CPVC 1/2" x 90 | 722020 | und | 0.7 |
| TEE CPVC 1/2" | 722040 | und | 1.01 |
| TUBERIA PVC-SAL PESADA DE 2" X 3M | 723001 | pza | 5.9 |
| TUBERIA PVC-SAL PESADA DE 4" X 3M | 723003 | pza | 10.5 |
| TUBERIA PVC-SAL PESADA DE 6" X 5M | 723004 | pza | 78.7 |
| CODO PVC C-5 2" X 90o (DESAGUE) | 723101 | und | 2.4 |
| CODO PVC C-5 4" X 90o (DESAGUE) | 723103 | und | 4.8 |
| RAMAL YEE SIMPLE PVC C-5 DE 4" (DESAGUE) | 723203 | und | 5.2 |
| RAMAL YEE DE PVC C-5 DE 4"x2" (DESAGUE) | 723238 | und | 3.8 |
| RAMAL TEE SIMPLE PVC C-5 DE 2" (DESAGUE) | 723301 | und | 3.8 |
| TEE SANITARIA DOBLE PVC C-5 4" (DESAGUE) | 723433 | und | 5.5 |
| UNION DOBLE PVC C-5 DE 2" (DESAGUE) | 723501 | und | 1.49 |
| UNION DOBLE PVC C-5 DE 4" (DESAGUE) | 723503 | und | 3.4 |
| UNION DOBLE PVC C-5 DE 6" (DESAGUE) | 723504 | und | 13.8 |
| TRAMPA P PVC C-5 DE 2" (DESAGUE) | 723601 | und | 12.3 |
| SOMBRERO DE VENTILACION PVC DE 2" | 723901 | und | 4.1 |
| TUBERIA PVC SAP (ELEC) 15 MM | 726031 | mL | 1.42 |
| TUBERIA PVC SAP (ELEC) 20 MM | 726032 | mL | 3.02 |
| TUBERIA PVC SAP (ELEC) 25 MM | 726033 | mL | 4.05 |
| TUBERIA PVC SAP (ELEC) 35 MM | 726034 | mL | 5.34 |
| TUBERIA PVC SAP (ELEC) 50 MM | 726036 | mL | 8.31 |
| TUBERIA PVC SAP (ELEC) 65 MM | 726037 | mL | 7.35 |
| CURVA PVC SAP P/INST. ELECT. DE 15MM | 726101 | und | 0.5 |
| CURVA PVC SAP P/INST. ELECT. DE 20MM | 726102 | und | 0.75 |
| CURVA PVC SAP P/INST. ELECT. DE 25MM | 726103 | und | 1.15 |
| CURVA PVC SAP P/INST. ELECT. DE 35MM | 726104 | und | 2.26 |
| CURVA PVC SAP P/INST. ELECT. DE 50MM | 726106 | und | 6.6 |
| CURVA PVC SAP P/INST. ELECT. DE 65MM | 726107 | und | 27.38 |
| UNION PVC SAP (ELEC) 20MM | 726202 | und | 0.66 |
| UNION PVC SAP (ELEC) 25MM | 726203 | und | 0.71 |
| UNION PVC SAP (ELEC) 35MM | 726204 | und | 1.47 |
| UNION PVC SAP (ELEC) 50MM | 726206 | und | 2.47 |
| UNION PVC SAP (ELEC) 65MM | 726207 | und | 6.7 |
| CONECTOR PVC SAP (ELEC) 15MM | 726301 | und | 0.5 |
| CONECTOR PVC SAP (ELEC) 20MM | 726302 | und | 0.83 |
| CONECTOR A CAJA PVC SEL (ELEC) 20MM | 727302 | und | 1.2 |
| TAPA CIEGA DE PLASTICO | 729010 | und | 2.46 |
| VALVULA COMPUERTA DE BRONCE DE 1/2" | 770001 | und | 11.35 |
| VALVULA COMPUERTA DE BRONCE DE 1 1/2" | 770005 | und | 32.3 |
| VALVULA COMPUERTA DE BRONCE DE 2" | 770006 | und | 48.82 |
| VALVULA CHECK HORIZONTAL DE BRONCE DE 1 1/2" | 770305 | und | 65.55 |
| REGISTRO ROSCADO DE BRONCE DE 4" | 773104 | pza | 7.5 |
| SUMIDERO DE BRONCE DE 2" | 773201 | pza | 5.1 |
| INSTALACION SANITARIA | 800101 | est | 120 |
| CONEXION A RED DE AGUA EXISTENTE | 800102 | glb | 55 |
| CONEXION A RED DE DESAGUE EXISTENTE | 800103 | glb | 300 |
| FLETE INTERPROVINCIAL | 810101 | ton | 125 |
| PINTURA ZINCROMATO | 830101 | gln | 33 |
| HELICOIDAL DE 9m Cu 1/10 | 850101 | und | 66.61 |
| MATERIALES DIVERSOS | 302908 | x1.00 | 1 |
| HERRAMIENTAS MANUALES | 370101 | x1.00 | 1 |
| CABLE DE COBRE DESNUDO TIPO SUAVE 16MM2 | 060205 | mL | 2.95 |
| CABLE DE COBRE DESNUDO TIPO SUAVE 6MM2 | 050209 | mL | 1.18 |
| CONEXION A RED EXISTENTE - INST. ELECTRICAS | 112401 | glb | 150 |
| MURETE PTA GAB ELECT 1.50x1.80x.25 | 170011 | und | 415 |
| OPERARIO ELECTRICISTA | 470118 |  | 10.16 |
| VOLQUETE 4X2 140-210 HP 6M3 | 481002 |  | 181.15 |
| BUZON DE CONCRETO | 625401 | und | 120 |
| CODO DE FIERRO GALVANIZADO DE 3/4 X 90o | 650204 | und | 1.69 |
| UNION UNIVERSAL DE FIERRO GALVANIZADO DE 3/4 | 650523 | und | 5.08 |
| NIPLE DE FIERRO GALVANIZADO DE 3/4"x 1 1/4" | 651311 | und | 0.68 |
| NIPLE DE FIERRO GALVANIZADO DE 2"X1 1/4" | 651314 | und | 2.22 |
| UNION UNIVERSAL CPVC AGUA CALIENTE 3/4 | 720345 | pza | 7.46 |
| ADAPTADOR CPVC A. CALIENTE MACHO PRESION 3/4" | 720804 | pza | 1.39 |
| TUBERIA CPVC 3/4" X 5m | 722002 | und | 49.93 |
| CODO CPVC 3/4" x 90 | 722041 | und | 2.02 |
| TEE CPVC 3/4" | 722042 | und | 2.4 |
| VALVULA COMPUERTA DE BRONCE DE 3/4" | 770002 | und | 13.22 |
| VALVULA CHECK HORIZONTAL DE BRONCE DE 2" | 770306 | und | 107.5 |
| VALVULA FLOTADORA DE 1.1/2" | 770522 | und | 135.33 |
| VALVULA ESFERICA DE BRONCE DE 2" | 770706 | und | 89.38 |
| CERRADURA TIPO H | 303848 | und | 26.9 |

## Schedule

| ID | WBS | Task | Duration | Start | Finish | Predecessors | Total slack | Free slack | Constraint | Resources | Work | Cost | Baseline cost |
| --- | --- | --- | --- | --- | --- | --- | --- | --- | --- | --- | --- | --- | --- |
| 2 | 1 | **OBRA: REHABILITACION, AMPLIACION Y EQUIPAMIENTO DEL CENTRO DE SALUD PUERTO NUEVO - CALLAO** | 120d? | 2007-05-01 | 2007-08-28 |  | 0d |  |  |  | 22202.5h | 780,816.51 |  |
| 3 | 1.1 | **INICIO** | 0d | 2007-05-01 | 2007-05-01 |  | 120d |  |  |  |  |  |  |
| 4 | 1.1.1 | **ESTRUCTURAS** | 80.5d | 2007-05-01 | 2007-07-20 |  | 0d |  |  |  | 10120.9h | 382,063.22 |  |
| 5 | 1.1.1.1 | **01.00 OBRAS PROVISIONALES** | 2d | 2007-05-01 | 2007-05-02 |  | 0d |  |  |  | 84h | 39,520.8 |  |
| 6 | 1.1.1.1.1 | CERCO PROVISIONAL DE TRIPLAY H=2.0M | 0.5d | 2007-05-02 | 2007-05-02 | 8 | 118d | 0d |  |  |  |  |  |
| 7 | 1.1.1.1.2 | CARTEL DE OBRA REGIÓN CALLAO DE 7.20m x 3.60m | 0.5d | 2007-05-02 | 2007-05-02 | 6 | 118d |  |  |  |  |  |  |
| 8 | 1.1.1.1.3 | ALQUILER DE ALMACÉN, OFICINA PROVISIONAL INC. SS.HH. | 1d | 2007-05-01 | 2007-05-01 |  | 0d |  |  |  |  |  |  |
| 9 | 1.1.1.1.4 | MOVILIZACIÓN Y DESMOVILIZACIÓN DE EQUIPOS Y HERRAMIENTAS | 1d | 2007-05-02 | 2007-05-02 | 8 | 0d |  |  | CAPATAZ [0.5 H.H]; OPERARIO [4 H.H]; OFICIAL [1 H.H]; PEON [5 H.H]; CLAVOS CON CABEZA PROMEDIO [429.83 kg]; PERNOS CON TUERCAS 5/8" X 10" [96.56 pza]; ARANDELAS DE 5/8" [96.56 pza]; PIEDRA MEDIANA [6.31 m3]; CEMENTO PORTLAND TIPO I (42.5 kg) [91.48 bol]; LIJA PARA MADERA [19.31 hja]; COLA SINTETICA [3.22 gln]; HORMIGON [37.21 m3]; MADERA TORNILLO [4940.78 p2]; TRIPLAY DE 4´x 8´x 4mm. [673.36 pln]; PINTURA ESMALTE [25.75 gln]; HERRAMIENTAS MANUALES [265.8 x1.00]; PLANCHA GRAN ONDA 1.83 M [257.5 pza]; GRIFO DE BRONCE DE 1/2" [6.44 und]; PERFIL 4 ETERNIT ROJO 2.44x1.10x4mm [32.19 pza]; INSTALACION SANITARIA [6.44 est] | 84h | 39,520.8 | 1,139.38 |
| 10 | 1.1.1.2 | **02.00 TRABAJOS PRELIMINARES** | 17d | 2007-05-03 | 2007-05-19 |  | 0d |  |  |  | 5319.81h | 152,843 |  |
| 11 | 1.1.1.2.1 | DEMOLICION DE CIMIENTOS DE CONCRETO | 2d | 2007-05-10 | 2007-05-11 | 12 | 7d |  |  | CAPATAZ [0.5 H.H]; OPERARIO [5 H.H]; PEON [10 H.H]; HERRAMIENTAS MANUALES [123.04 x1.00] | 248.05h | -889.57 |  |
| 12 | 1.1.1.2.2 | DEMOLICION DE SOBRECIMIENTO MANUAL | 1d | 2007-05-09 | 2007-05-09 | 14 | 0d |  |  | CAPATAZ [0.4 H.H]; PEON [4 H.H]; HERRAMIENTAS MANUALES [449.93 x1.00]; COMPRESORA NEUMATICA [2 H-M]; MARTILLO NEUMATICO [2 H-M]; OPERARIO [2 H.H]; OFICIAL [2 H.H] | 99.2h | 4,028.6 |  |
| 13 | 1.1.1.2.3 | DEMOLICION DE MURO DE LADRILLO CABEZA | 2d | 2007-05-07 | 2007-05-08 | 21 | 10d |  |  |  |  |  |  |
| 14 | 1.1.1.2.4 | DEMOLICION DE MURO DE LADRILLO SOGA | 2d | 2007-05-07 | 2007-05-08 | 21 | 0d |  |  |  |  |  |  |
| 15 | 1.1.1.2.5 | DESMONTAJE DE TABIQUES DE MADERA | 1d | 2007-05-03 | 2007-05-03 | 9 | 7d |  |  | CAPATAZ [18.1 H.H]; PEON [181 H.H]; HERRAMIENTAS MANUALES [407.94 x1.00] | 1592.8h | 7,956.25 |  |
| 16 | 1.1.1.2.6 | DESMONTAJE DE PUERTAS DE MADERA | 1d | 2007-05-03 | 2007-05-03 | 9 | 7d |  |  | CAPATAZ [0.82 H.H]; OPERARIO [8.2 H.H]; PEON [8.2 H.H]; CLAVOS CON CABEZA PROMEDIO [6.55 kg]; MADERA TORNILLO [19.65 p2]; HERRAMIENTAS MANUALES [38.42 x1.00]; COMPACTADOR VIBRATORIO TIPO PLANCHA 4HP [8.2 HM.] | 203.36h | 2,510.48 | 101.28 |
| 17 | 1.1.1.2.7 | DESMONTAJE DE PUERTAS METÁLICAS | 1d | 2007-05-03 | 2007-05-03 | 9 | 0d |  |  |  |  |  |  |
| 18 | 1.1.1.2.8 | DESMONTAJE DE PUERTAS DE REJA METÁLICA | 1d | 2007-05-04 | 2007-05-04 | 17 | 6d |  |  |  |  |  |  |
| 19 | 1.1.1.2.9 | DESMONTAJE DE REJA METÁLICA | 1d | 2007-05-04 | 2007-05-04 | 17 | 6d |  |  | CAPATAZ [0.1 H.H]; OPERARIO [2 H.H]; OFICIAL [1 H.H]; PEON [6 H.H]; CEMENTO PORTLAND TIPO I (42.5 kg) [0.54 bol]; AGUA [0.03 m3]; HORMIGON [0.35 m3]; HERRAMIENTAS MANUALES [1.27 x1.00]; MEZCLADORA DE CONCRETO TAMBOR 11 p3 22 HP [1 HM.] | 80.8h | 868.79 | 324.57 |
| 20 | 1.1.1.2.10 | DESMONTAJE DE VENTANAS DE REJA METÁLICA | 2d | 2007-05-04 | 2007-05-05 | 17 | 0d |  |  | CAPATAZ [0.1 H.H]; OPERARIO [2 H.H]; OFICIAL [2 H.H]; PEON [8 H.H]; PIEDRA GRANDE [55.5 m3]; CEMENTO PORTLAND TIPO I (42.5 kg) [336 bol]; AGUA [17.63 m3]; HORMIGON [96 m3]; HERRAMIENTAS MANUALES [112.08 x1.00]; MEZCLADORA DE CONCRETO TOLVA 11P3 [1 HM.] | 209.6h | 16,504.28 | 324.57 |
| 21 | 1.1.1.2.11 | DESMONTAJE DE APARATOS SANITARIOS | 1d | 2007-05-06 | 2007-05-06 | 20 | 0d |  |  |  |  |  |  |
| 22 | 1.1.1.2.12 | DESMONTAJE DE LUMINARIAS | 2d | 2007-05-03 | 2007-05-04 | 9 | 6d | 0d |  | CAPATAZ [0.1 H.H]; OPERARIO [2 H.H]; OFICIAL [1 H.H]; PEON [8 H.H]; OPERADOR DE EQUIPO LIVIANO [2 H.H.]; ARENA GRUESA [11.79 m3]; PIEDRA CHANCADA [18.86 m3]; CEMENTO PORTLAND TIPO I (42.5 kg) [216.94 bol]; AGUA [4.34 m3]; HERRAMIENTAS MANUALES [32.59 x1.00]; MEZCLADORA DE CONCRETO TAMBOR 11 p3 22 HP [1 HM.]; VIBRADORA DE CONCRETO 4 HP 2.40" [1 HM.] | 241.6h | 9,505.49 | 78.91 |
| 23 | 1.1.1.2.13 | DEMOLICION DE CONTRAZÓCALO CONCRETO PULIDO H=0.10M | 0.5d | 2007-05-05 | 2007-05-05 | 22 | 113.5d | 0d |  | CAPATAZ [12.2 H.H]; OPERARIO [122 H.H]; OFICIAL [122 H.H]; ALAMBRE NEGRO RECOCIDO # 8 [182.93 kg]; CLAVOS CON CABEZA PROMEDIO [103.66 kg]; MADERA TORNILLO [2463.51 p2]; HERRAMIENTAS MANUALES [299.57 x1.00] | 1024.8h | 23,041.9 |  |
| 24 | 1.1.1.2.14 | DEMOLICION DE PISO DE CONCRETO E=0.15 m | 1d | 2007-05-05 | 2007-05-06 | 23 | 113.5d | 12.5d |  | CAPATAZ [2.28 H.H]; OPERARIO [22.8 H.H]; OFICIAL [22.8 H.H]; ALAMBRE NEGRO RECOCIDO # 16 [383 kg]; ACERO CORRUGADO FY=4200 Kg/cm2 GRADO 60 [6829 kg]; HERRAMIENTAS MANUALES [186.63 x1.00] | 383.04h | 27,752.42 |  |
| 25 | 1.1.1.2.15 | DEMOLICION DE GRADAS Y VEREDAS DE CONCRETO H=0.15 m | 1d | 2007-05-05 | 2007-05-06 | 23 | 114.5d |  |  |  |  |  |  |
| 26 | 1.1.1.2.16 | APERTURA DE VANOS EN MURO DE CABEZA | 1d | 2007-05-19 | 2007-05-19 | 20, 24, 39 | 101d |  |  | CAPATAZ [0.1 H.H]; OPERARIO [2 H.H]; OFICIAL [1 H.H]; PEON [12 H.H]; OPERADOR DE EQUIPO LIVIANO [2 H.H.]; ARENA GRUESA [20.9 m3]; PIEDRA CHANCADA [20.9 m3]; CEMENTO PORTLAND TIPO I (42.5 kg) [337.3 bol]; AGUA [6.75 m3]; HERRAMIENTAS MANUALES [130.44 x1.00]; MEZCLADORA DE CONCRETO TAMBOR 11 p3 22 HP [1 HM.]; VIBRADORA DE CONCRETO 4 HP 2.40" [1 HM.] | 152.8h | 13,634.58 |  |
| 27 | 1.1.1.2.17 | DEMOLICION DE LOSA ALIGERADA H=0.20M | 1d | 2007-05-03 | 2007-05-03 | 9 | 14d | 3.5d |  | CAPATAZ [4.69 H.H]; OPERARIO [46.91 H.H]; OFICIAL [46.91 H.H]; ALAMBRE NEGRO RECOCIDO # 8 [140.75 kg]; CLAVOS CON CABEZA PROMEDIO [79.76 kg]; MADERA TORNILLO [1989.2 p2]; HERRAMIENTAS MANUALES [230.48 x1.00] | 788.09h | 18,004.2 |  |
| 28 | 1.1.1.2.18 | DEMOLICION DE VIGAS DE CONCRETO | 1d | 2007-05-07 | 2007-05-08 | 9, 30 | 10.5d |  |  | CAPATAZ [0.4 H.H]; OPERARIO [4 H.H]; OFICIAL [4 H.H]; ALAMBRE NEGRO RECOCIDO # 16 [352.77 kg]; ACERO CORRUGADO FY=4200 Kg/cm2 GRADO 60 [6291 kg]; HERRAMIENTAS MANUALES [171.93 x1.00] | 67.2h | 22,767.03 |  |
| 29 | 1.1.1.2.19 | DEMOLICION DE COLUMNAS DE CONCRETO | 1d | 2007-05-07 | 2007-05-08 | 27, 30 | 10.5d |  | start no earlier than 2006-09-17 | CAPATAZ [0.2 H.H]; OPERARIO [2 H.H]; OFICIAL [1 H.H]; PEON [8 H.H]; OPERADOR DE EQUIPO LIVIANO [2 H.H.]; ARENA GRUESA [1.69 m3]; PIEDRA CHANCADA [1.69 m3]; CEMENTO PORTLAND TIPO I (42.5 kg) [22.2 bol]; AGUA [0.89 m3]; HERRAMIENTAS MANUALES [8.26 x1.00]; MEZCLADORA DE CONCRETO TAMBOR 11 p3 22 HP [1 HM.]; VIBRADORA DE CONCRETO 4 HP 2.40" [0.5 HM.] | 117.6h | 1,965.1 |  |
| 30 | 1.1.1.2.20 | APUNTALAMIENTO METÁLICO | 0.5d | 2007-05-07 | 2007-05-07 | 21 | 10.5d | 0d |  | CAPATAZ [1.22 H.H]; OPERARIO [12.2 H.H]; OFICIAL [12.2 H.H]; ALAMBRE NEGRO RECOCIDO # 8 [18.36 kg]; CLAVOS CON CABEZA PROMEDIO [10.4 kg]; MADERA TORNILLO [259.49 p2]; HERRAMIENTAS MANUALES [30.07 x1.00] | 102.48h | 2,344.09 |  |
| 31 | 1.1.1.2.21 | TRAZO, NIVELES Y REPLANTEO | 0.5d | 2007-05-12 | 2007-05-12 | 34 | 108.5d |  |  | CAPATAZ [0.1 H.H]; OPERARIO [1 H.H]; OFICIAL [1 H.H]; ALAMBRE NEGRO RECOCIDO # 16 [44.05 kg]; ACERO CORRUGADO FY=4200 Kg/cm2 GRADO 60 [787.57 kg]; HERRAMIENTAS MANUALES [21.47 x1.00] | 8.4h | 2,849.35 |  |

| ID | WBS | Task | Duration | Start | Finish | Predecessors | Total slack | Free slack | Constraint | Resources | Work | Cost |
| --- | --- | --- | --- | --- | --- | --- | --- | --- | --- | --- | --- | --- |
| 32 | 1.1.1.3 | **3.00 MOVIMIENTO DE TIERRAS** | 12d | 2007-05-10 | 2007-05-21 |  | 0d |  |  | CAPATAZ [0.2 H.H]; OPERARIO [2 H.H]; OFICIAL [1 H.H]; PEON [12 H.H]; OPERADOR DE EQUIPO LIVIANO [2 H.H.]; ARENA GRUESA [17.42 m3]; PIEDRA CHANCADA [35.25 m3]; CEMENTO PORTLAND TIPO I (42.5 kg) [393.97 bol]; AGUA [7.63 m3]; HERRAMIENTAS MANUALES [74.33 x1.00]; MEZCLADORA DE CONCRETO TOLVA 11P3 [1 HM.]; VIBRADORA DE CONCRETO 4 HP 2.40" [1 HM.] | 4717.11h | 189,699.42 |
| 33 | 1.1.1.3.1 | **LIMPIEZA** | 1d | 2007-05-11 | 2007-05-11 |  | 0d |  |  |  | 98.46h | 44,383.77 |
| 34 | 1.1.1.3.1.1 | LIMPIEZA DE TERRENO MANUAL | 1d | 2007-05-11 | 2007-05-11 | 36, 15, 16, 17, 18, 19, 20, 21, 22 | 0d |  |  | CAPATAZ [0.3 H.H]; OPERARIO [3 H.H]; PEON [6 H.H]; TIRAFONES 5" C/ARANDELA PLASTICA P/TEJA [1117 und]; PLANCHA TEJA ANDINA FIBROCEMENTO 1.16x .72 [1022 und]; HERRAMIENTAS MANUALES [151.17 x1.00]; OFICIAL [3 H.H] | 98.46h | 44,383.77 |
| 35 | 1.1.1.3.2 | **EXCAVACIONES** | 1d | 2007-05-10 | 2007-05-10 |  | 0d |  |  |  | 16.8h | 8,215.55 |
| 36 | 1.1.1.3.2.1 | EXCAVACION DE SUPERFICIE MANUAL | 1d | 2007-05-10 | 2007-05-10 | 12 | 0d |  |  | CAPATAZ [0.1 H.H]; OPERARIO [1 H.H]; PEON [1 H.H]; TIRAFONES 5" C/ARANDELA PLASTICA P/TEJA [111 und]; CUMBRERA SUPERIOR TEJA ANDINA FIBROCEMENTO [135 und]; CUMBRERA INFERIOR TEJA ANDINA FIBROCEMENTO [135 und]; PERNO 1/2"x3" CON TUERCA [657 und]; TARUGO 1 1/2" x 2" [657 und]; MADERA TORNILLO CEPILLADA [135 p2]; HERRAMIENTAS MANUALES [20.68 x1.00] | 16.8h | 8,215.55 |
| 37 | 1.1.1.3.3 | **EXCAVACION DE TERRAPLENES CON EQUIPO** | 1d | 2007-05-12 | 2007-05-12 |  | 0d |  |  |  | 2758.66h | 106,766.41 |
| 38 | 1.1.1.3.3.1 | EXCAVACION DE ZANJA PARA CIMIENTO HASTA 1.40M TERRENO NORMAL | 1d | 2007-05-12 | 2007-05-12 | 34 | 0d |  | start no earlier than 2006-09-17 | CAPATAZ [21.55 H.H]; OPERARIO [215.52 H.H]; PEON [107.76 H.H]; CLAVOS CON CABEZA PROMEDIO [3.75 kg]; ARENA GRUESA [71.2 m3]; LADRILLO KK 18 HUECOS HECHO A MAQUINA 9X13X23 [92422 und]; CEMENTO PORTLAND TIPO I (42.5 kg) [505.5 bol]; AGUA [14.01 m3]; MADERA TORNILLO [768.71 p2]; HERRAMIENTAS MANUALES [798 x1.00] | 2758.66h | 106,766.41 |
| 39 | 1.1.1.3.4 | **MEJORAMIENTO DE SUELOS** | 6d | 2007-05-13 | 2007-05-18 |  | 0d |  |  |  |  |  |
| 40 | 1.1.1.3.4.1 | ESCARIFICADO Y COMPACTACIÓN DE SUBRASANTE E=0.40 C/EQUIPO P/EDIFICACION | 2d | 2007-05-13 | 2007-05-14 | 38 | 0d |  |  |  |  |  |
| 41 | 1.1.1.3.4.2 | BASE GRANULAR E=0.20 m C/EQUIPO P/EDIFICACION | 2d | 2007-05-15 | 2007-05-16 | 40 | 0d |  |  |  |  |  |
| 42 | 1.1.1.3.4.3 | BASE GRANULAR E=0.20 m C/RODILLO LISO MANUAL 10.8HP | 2d | 2007-05-17 | 2007-05-18 | 41 | 0d |  |  |  |  |  |
| 43 | 1.1.1.3.5 | **ELIMINACIÓN DE MATERIAL EXCEDENTE** | 3d | 2007-05-19 | 2007-05-21 |  | 0d |  |  |  |  |  |
| 44 | 1.1.1.3.5.1 | ACARREO MATERIAL PROCEDENTE DE DEMOLICIONES | 1d | 2007-05-19 | 2007-05-19 | 42, 13, 11, 12, 27, 28, 29 | 0d |  |  |  |  |  |
| 45 | 1.1.1.3.5.2 | TRANSPORTE VERTICAL Y HORIZONTAL DE MATERIALES EN OBRA | 1d | 2007-05-20 | 2007-05-20 | 44 | 0d |  |  |  |  |  |
| 46 | 1.1.1.3.5.3 | ELIMINACION DE MATERIAL EXCEDENTE CON MÁQUINA V=40KPH D=30 km | 1d | 2007-05-21 | 2007-05-21 | 45 | 0d |  |  |  |  |  |
| 47 | 1.1.1.4 | **4.00 CONCRETO SIMPLE** | 4d | 2007-05-22 | 2007-05-25 |  | 0d |  |  |  |  |  |
| 48 | 1.1.1.4.1 | CIMIENTOS CORRIDOS | 1d | 2007-05-23 | 2007-05-23 | 49 | 0d |  |  |  |  |  |
| 49 | 1.1.1.4.2 | SUBCIMIENTOS | 1d | 2007-05-22 | 2007-05-22 | 46 | 0d |  |  |  |  |  |
| 50 | 1.1.1.4.3 | **SOBRECIMIENTOS** | 2d | 2007-05-24 | 2007-05-25 |  | 43d |  |  |  |  |  |
| 51 | 1.1.1.4.3.1 | CONCRETO 1:8+25% PM PARA SOBRECIMIENTOS f`c=140kg/cm2 TIPO V | 0.5d | 2007-05-25 | 2007-05-25 | 52 | 43d | 0d |  |  |  |  |
| 52 | 1.1.1.4.3.2 | ENCOFRADO Y DESENCOFRADO PARA SOBRECIMIENTOS HASTA 0.30M | 1.5d | 2007-05-24 | 2007-05-25 | 48 | 43d | 0d |  |  |  |  |
| 53 | 1.1.1.5 | **5.00 CONCRETO ARMADO** | 62.5d | 2007-05-19 | 2007-07-20 |  | 15d |  |  |  |  |  |
| 54 | 1.1.1.5.1 | **VIGAS DE CIMENTACIÓN** | 2d | 2007-05-19 | 2007-05-20 |  | 15d |  |  |  |  |  |
| 55 | 1.1.1.5.1.1 | CONCRETO EN VIGAS DE CIMENTACION f'c=210 kg/cm2 TIPO V | 1d | 2007-05-20 | 2007-05-20 | 56 | 15d | 0d |  |  |  |  |
| 56 | 1.1.1.5.1.2 | ENCOFRADO Y DESENCOFRADO PARA VIGAS DE CIMENTACION | 1d | 2007-05-19 | 2007-05-19 | 42 | 15d | 0d |  |  |  |  |
| 57 | 1.1.1.5.1.3 | ACERO CORRUGADO EN VIGA DE CIMENTACIÓN fy=4200 kg/cm2 GRADO 60 | 1d | 2007-05-19 | 2007-05-19 | 8, 42 | 96d | 0d |  |  |  |  |

| ID | WBS | Task | Duration | Start | Finish | Predecessors | Total slack | Free slack |
| --- | --- | --- | --- | --- | --- | --- | --- | --- |
| 58 | 1.1.1.5.2 | **LOSAS DE CIMENTACIÓN** | 6.5d | 2007-05-20 | 2007-05-26 |  | 16d |  |
| 59 | 1.1.1.5.2.1 | CONCRETO EN LOSAS DE CIMENTACION f'c=210 kg/cm2 TIPO V | 1d | 2007-05-25 | 2007-05-26 | 60, 97 | 12.5d | 0d |
| 60 | 1.1.1.5.2.2 | ENCOFRADO Y DESENCOFRADO EN LOSAS DE CIMENTACIÓN | 2d | 2007-05-21 | 2007-05-22 | 55 | 15d | 2.5d |
| 61 | 1.1.1.5.2.3 | ACERO CORRUGADO EN LOSA DE CIMENTACIÓN fy=4200 kg/cm2 GRADO 60 | 5d | 2007-05-20 | 2007-05-24 | 57 | 96d |  |
| 62 | 1.1.1.5.3 | **PLACAS** | 9d | 2007-05-26 | 2007-06-04 |  | 76.5d |  |
| 63 | 1.1.1.5.3.1 | CONCRETO EN PLACAS f'c=210 kg/cm2 TIPO V | 3d | 2007-06-01 | 2007-06-04 | 64 | 79.5d | 0d |
| 64 | 1.1.1.5.3.2 | ENCOFRADO Y DESENCOFRADO EN PLACAS | 3d | 2007-05-29 | 2007-06-01 | 65 | 76.5d | 0d |
| 65 | 1.1.1.5.3.3 | ACERO CORRUGADO EN PLACAS fy=4200 kg/cm2 GRADO 60 | 3d | 2007-05-26 | 2007-05-29 | 59 | 76.5d | 0d |
| 66 | 1.1.1.5.4 | **COLUMNAS** | 15d | 2007-05-26 | 2007-06-10 |  | 12.5d |  |
| 67 | 1.1.1.5.4.1 | CONCRETO EN COLUMNAS f'c=210 kg/cm2 TIPO V | 3d | 2007-06-07 | 2007-06-10 | 68 | 12.5d | 0d |
| 68 | 1.1.1.5.4.2 | ENCOFRADO Y DESENCOFRADO EN COLUMNAS | 6d | 2007-06-01 | 2007-06-07 | 69 | 12.5d | 0d |
| 69 | 1.1.1.5.4.3 | ACERO CORRUGADO EN COLUMNAS fy=4200 kg/cm2 GRADO 60 | 6d | 2007-05-26 | 2007-06-01 | 59 | 12.5d | 0d |
| 70 | 1.1.1.5.5 | **COLUMNETAS** | 14d | 2007-07-01 | 2007-07-15 |  | 27.5d |  |
| 71 | 1.1.1.5.5.1 | CONCRETO EN COLUMNAS f'c=175 kg/cm2 TIPO V | 2d | 2007-07-13 | 2007-07-15 | 72 | 39.5d | 0d |
| 72 | 1.1.1.5.5.2 | ENCOFRADO Y DESENCOFRADO EN COLUMNAS | 8d | 2007-07-05 | 2007-07-13 | 73 | 27.5d | 0d |
| 73 | 1.1.1.5.5.3 | ACERO CORRUGADO EN COLUMNAS fy=4200 kg/cm2 GRADO 60 | 4d | 2007-07-01 | 2007-07-05 | 124 | 27.5d | 0d |
| 74 | 1.1.1.5.6 | **VIGAS** | 15d | 2007-06-10 | 2007-06-25 |  | 64.5d |  |
| 75 | 1.1.1.5.6.1 | CONCRETO EN VIGAS f'c=210 kg/cm2 TIPO V | 3d | 2007-06-22 | 2007-06-25 | 76 | 64.5d |  |
| 76 | 1.1.1.5.6.2 | ENCOFRADO Y DESENCOFRADO EN VIGAS | 6d | 2007-06-16 | 2007-06-22 | 77 | 64.5d | 0d |
| 77 | 1.1.1.5.6.3 | ACERO CORRUGADO EN VIGAS fy=4200 kg/cm2 GRADO 60 | 6d | 2007-06-10 | 2007-06-16 | 67 | 64.5d | 0d |
| 78 | 1.1.1.5.7 | **VIGUETAS DE AMARRE Y COLGAJOS** | 5d | 2007-07-15 | 2007-07-20 |  | 39.5d |  |
| 79 | 1.1.1.5.7.1 | CONCRETO EN VIGAS f'c=175 kg/cm2 TIPO V | 1d | 2007-07-19 | 2007-07-20 | 80, 81 | 39.5d |  |
| 80 | 1.1.1.5.7.2 | ENCOFRADO Y DESENCOFRADO EN VIGAS | 3d | 2007-07-16 | 2007-07-19 | 81 | 39.5d | 0d |
| 81 | 1.1.1.5.7.3 | ACERO CORRUGADO EN VIGAS fy=4200 kg/cm2 GRADO 60 | 1d | 2007-07-15 | 2007-07-16 | 71 | 39.5d | 0d |

| ID | WBS | Task | Duration | Start | Finish | Predecessors | Total slack | Free slack |
| --- | --- | --- | --- | --- | --- | --- | --- | --- |
| 82 | 1.1.1.5.8 | **LOSAS ALIGERADAS H=0.20M** | 12d | 2007-06-10 | 2007-06-22 |  | 12.5d |  |
| 83 | 1.1.1.5.8.1 | CONCRETO EN LOSAS ALIGERADAS f'c=210 kg/cm2 TIPO V | 3d | 2007-06-19 | 2007-06-22 | 85, 86 | 12.5d | 0d |
| 84 | 1.1.1.5.8.2 | ENCOFRADO Y DESENCOFRADO EN LOSAS ALIGERADAS | 3d | 2007-06-10 | 2007-06-13 | 67, 68 | 12.5d | 0d |
| 85 | 1.1.1.5.8.3 | ACERO CORRUGADO EN LOSAS ALIGERADAS fy=4200 kg/cm2 GRADO 60 | 3d | 2007-06-16 | 2007-06-19 | 86 | 12.5d | 0d |
| 86 | 1.1.1.5.8.4 | LADRILLO HUECO DE ARCILLA 15X30X30 CM PARA TECHO ALIGERADO | 3d | 2007-06-13 | 2007-06-16 | 84 | 12.5d | 0d |
| 87 | 1.1.1.5.9 | **LOSAS ALIGERADAS H=0.17M** | 12d | 2007-06-10 | 2007-06-22 |  | 52.5d |  |
| 88 | 1.1.1.5.9.1 | CONCRETO EN LOSAS ALIGERADAS f'c=210 kg/cm2 TIPO V | 3d | 2007-06-19 | 2007-06-22 | 90, 91 | 55.5d | 0d |
| 89 | 1.1.1.5.9.2 | ENCOFRADO Y DESENCOFRADO EN LOSAS ALIGERADAS | 3d | 2007-06-10 | 2007-06-13 | 67 | 52.5d | 0d |
| 90 | 1.1.1.5.9.3 | ACERO CORRUGADO EN LOSAS ALIGERADAS fy=4200 kg/cm2 GRADO 60 | 3d | 2007-06-16 | 2007-06-19 | 91 | 52.5d | 0d |
| 91 | 1.1.1.5.9.4 | LADRILLO HUECO DE ARCILLA 12X30X30 CM PARA TECHO ALIGERADO | 3d | 2007-06-13 | 2007-06-16 | 89 | 52.5d | 0d |
| 92 | 1.1.1.5.10 | **LOSA MACIZA H=0.15M** | 2d | 2007-06-22 | 2007-06-24 |  | 65.5d |  |
| 93 | 1.1.1.5.10.1 | CONCRETO EN LOSAS MACIZAS f'c=210 kg/cm2 TIPO V | 1d | 2007-06-23 | 2007-06-24 | 94 | 65.5d |  |
| 94 | 1.1.1.5.10.2 | ENCOFRADO Y DESENCOFRADO EN LOSAS MACIZAS | 1d | 2007-06-22 | 2007-06-23 | 88 | 65.5d | 0d |
| 95 | 1.1.1.5.10.3 | ACERO CORRUGADO EN LOSAS MACIZAS fy=4200 kg/cm2 GRADO 60 | 1d | 2007-06-22 | 2007-06-23 | 88 | 66.5d |  |
| 96 | 1.1.1.5.11 | **CISTERNA** | 2.5d | 2007-05-23 | 2007-05-25 |  | 12.5d |  |
| 97 | 1.1.1.5.11.1 | CONCRETO EN CISTERNA f'c=210 kg/cm2 TIPO V | 0.5d | 2007-05-25 | 2007-05-25 | 99 | 12.5d | 0d |
| 98 | 1.1.1.5.11.2 | ENCOFRADO Y DESENCOFRADO EN CISTERNA | 1d | 2007-05-23 | 2007-05-23 | 49 | 12.5d | 0d |
| 99 | 1.1.1.5.11.3 | ACERO CORRUGADO EN CISTERNA fy=4200 kg/cm2 GRADO 60 | 1d | 2007-05-24 | 2007-05-24 | 98 | 12.5d | 0d |
| 100 | 1.1.1.5.11.4 | JUNTA DE CONSTRUCCION CON WATER STOP | 1d | 2007-05-23 | 2007-05-23 | 98FF | 95d | 1.5d |
| 101 | 1.1.1.5.12 | **GRADAS Y ESCALERAS** | 9d | 2007-06-19 | 2007-06-28 |  | 52.5d |  |
| 102 | 1.1.1.5.12.1 | CONCRETO EN ESCALERAS f'c=210 kg/cm2 TIPO V | 3d | 2007-06-25 | 2007-06-28 | 103, 104 | 52.5d | 0d |
| 103 | 1.1.1.5.12.2 | ENCOFRADO Y DESENCOFRADO EN ESCALERAS | 3d | 2007-06-19 | 2007-06-22 | 90 | 52.5d | 0d |
| 104 | 1.1.1.5.12.3 | ACERO CORRUGADO EN ESCALERAS fy=4200 kg/cm2 GRADO 60 | 3d | 2007-06-22 | 2007-06-25 | 103 | 52.5d | 0d |
| 105 | 1.1.1.6 | **6.00 ANCLAJE DE COLUMNAS EN CONCRETO EXISTENTE** | 23d | 2007-05-07 | 2007-05-30 |  | 90.5d |  |
| 106 | 1.1.1.6.1 | **ANCLAJE DE COLUMNAS EN CIMIENTO** | 1.5d | 2007-05-07 | 2007-05-08 |  | 112d |  |
| 107 | 1.1.1.6.1.1 | PICADO DE CIMIENTO DE CONCRETO MANUAL | 0.5d | 2007-05-07 | 2007-05-07 | 30 | 112d | 0d |
| 108 | 1.1.1.6.1.2 | ENCOFRADO PARA RESANE DE CIMIENTO | 0.5d | 2007-05-08 | 2007-05-08 | 107 | 112d | 0d |
| 109 | 1.1.1.6.1.3 | RESANE DE CIMIENTO DE CONCRETO f'c=210 kg/cm2 TIPO V | 0.5d | 2007-05-08 | 2007-05-08 | 108 | 112d |  |

| ID | WBS | Task | Duration | Start | Finish | Predecessors | Total slack | Free slack | Resources | Work | Cost |
| --- | --- | --- | --- | --- | --- | --- | --- | --- | --- | --- | --- |
| 110 | 1.1.1.6.2 | **ANCLAJE DE COLUMNAS EN VIGA** | 2.5d | 2007-05-07 | 2007-05-09 |  | 111d |  |  |  |  |
| 111 | 1.1.1.6.2.1 | ACERO CORRUGADO DE EMPALME fy=4200 kg/cm2 GRADO 60 | 0.5d | 2007-05-07 | 2007-05-07 | 30 | 111d | 0d |  |  |  |
| 112 | 1.1.1.6.2.2 | COLOCACIÓN DE DOWELS EN VIGA EXISTENTE H=0.30M | 0.5d | 2007-05-08 | 2007-05-08 | 111 | 111d | 0d |  |  |  |
| 113 | 1.1.1.6.2.3 | ENCOFRADO PARA RESANE DE VIGA | 0.5d | 2007-05-08 | 2007-05-08 | 112 | 111d | 0d |  |  |  |
| 114 | 1.1.1.6.2.4 | UNIÓN CONCRETO ANTIGUO Y NUEVO CON ADITIVO EPÓXICO | 0.5d | 2007-05-09 | 2007-05-09 | 113 | 111d | 0d |  |  |  |
| 115 | 1.1.1.6.2.5 | RESANE DE VIGA DE CONCRETO f'c=210 kg/cm2 TIPO V | 0.5d | 2007-05-09 | 2007-05-09 | 114 | 111d |  |  |  |  |
| 116 | 1.1.1.6.3 | **ANCLAJE DE COLGAJOS EN VIGA** | 2.5d | 2007-05-28 | 2007-05-30 |  | 85.5d |  |  |  |  |
| 117 | 1.1.1.6.3.1 | ACERO CORRUGADO DE EMPALME fy=4200 kg/cm2 GRADO 60 | 0.5d | 2007-05-28 | 2007-05-28 | 123 | 85.5d | 0d |  |  |  |
| 118 | 1.1.1.6.3.2 | COLOCACIÓN DE DOWELS EN VIGA EXISTENTE H=0.20M | 0.5d | 2007-05-28 | 2007-05-28 | 117 | 85.5d | 0d |  |  |  |
| 119 | 1.1.1.6.3.3 | ENCOFRADO PARA RESANE DE VIGA | 0.5d | 2007-05-29 | 2007-05-29 | 118 | 85.5d | 0d |  |  |  |
| 120 | 1.1.1.6.3.4 | UNIÓN CONCRETO ANTIGUO Y NUEVO CON ADITIVO EPÓXICO | 0.5d | 2007-05-29 | 2007-05-29 | 119 | 85.5d | 0d |  |  |  |
| 121 | 1.1.1.6.3.5 | RESANE DE VIGA DE CONCRETO f'c=210 kg/cm2 TIPO V | 0.5d | 2007-05-30 | 2007-05-30 | 120 | 85.5d | 0d |  |  |  |
| 122 | 1.1.1.7 | **7.00 MUROS** | 36.5d | 2007-05-26 | 2007-07-01 |  | 43d |  |  |  |  |
| 123 | 1.1.1.7.1 | MURO DE LADRILLO KK DE ARCILLA DE CABEZA C/MEZCLA 1:4 X 1.5 cm | 2d | 2007-05-26 | 2007-05-27 | 51 | 85.5d | 0d |  |  |  |
| 124 | 1.1.1.7.2 | MURO DE LADRILLO KK DE ARCILLA DE SOGA C/MEZCLA 1:4 X 1.5 cm | 21d | 2007-06-10 | 2007-07-01 | 51, 67 | 27.5d | 0d |  |  |  |
| 125 | 1.1.1.8 | **8.00 VARIOS** | 2d | 2007-05-01 | 2007-05-02 |  | 103d | 70.5d |  |  |  |
| 126 | 1.1.1.8.1 | GARGOLAS SEGÚN DISEÑO f´c=210KG/CM2 TIPO V | 1d | 2007-05-01 | 2007-05-01 |  | 104d |  |  |  |  |
| 127 | 1.1.1.8.2 | DESMONTAJE Y MONTAJE DE ANTENA DE RADIO | 2d | 2007-05-01 | 2007-05-02 |  | 103d |  |  |  |  |
| 128 | 1.1.2 | **ARQUITECTURA** | 120d? | 2007-05-01 | 2007-08-28 |  | 0d |  |  | 8859.39h | 275,744.42 |
| 129 | 1.1.2.1 | **01.00 REVOQUES Y ENLUCIDOS** | 59d | 2007-05-25 | 2007-07-23 |  | 36.5d |  |  | 321.69h | 6,274.26 |
| 130 | 1.1.2.1.1 | TARRAJEO PRIMARIO RAYADO C:A 1:4 | 12d | 2007-07-11 | 2007-07-23 | 124FS+10d, 140 | 30.5d | 0d |  |  |  |
| 131 | 1.1.2.1.2 | TARRAJEO EN MUROS INTERIORES ACABADO DE C:A 1:4 E=1.5 CM | 4d | 2007-07-08 | 2007-07-12 | 140 | 12.5d | 0d |  |  |  |
| 132 | 1.1.2.1.3 | TARRAJEO EN MUROS EXTERIORES C/MORTERO C:A 1:4 E=1.5 CM | 3d | 2007-07-12 | 2007-07-15 | 131 | 34.5d | 0d |  |  |  |
| 133 | 1.1.2.1.4 | TARRAJEO DE SUPERF. VIGAS PERALTADAS C:A 1:4 E=1.5CM | 12d | 2007-07-08 | 2007-07-20 | 140 | 36.5d | 0d |  |  |  |
| 134 | 1.1.2.1.5 | TARRAJEO DE SUPERFICIE DE PLACAS Y COLUMNAS C:A 1:4 E=1.5 CM | 3d | 2007-07-20 | 2007-07-23 | 133 | 36.5d |  | CAPATAZ [0.94 H.H]; OPERARIO [9.37 H.H]; PEON [3.09 H.H]; CLAVOS CON CABEZA PROMEDIO [7.59 kg]; ARENA FINA [4.56 m3]; CEMENTO PORTLAND TIPO I (42.5 kg) [32.14 bol]; AGUA [1.09 m3]; MADERA PARA REGLAS (CEDRO) [6.33 p2]; MADERA TORNILLO [227.77 p2]; HERRAMIENTAS MANUALES [94.54 x1.00] | 321.69h | 6,274.26 |
| 135 | 1.1.2.1.6 | TARRAJEO DE MURO CON IMPERMEABILIZANTE | 2d | 2007-05-25 | 2007-05-27 | 97, 100 | 93.5d |  |  |  |  |
| 136 | 1.1.2.1.7 | VESTIDURA DE FONDO DE ESCALERA C/MORTERO C:A 1:4 E=1.5 CM | 9d | 2007-06-28 | 2007-07-07 | 102 | 52.5d |  |  |  |  |
| 137 | 1.1.2.1.8 | VESTIDURA DE DERRAMES ANCHO=0.15 M MEZC. C:A 1:4 E=1.5 CM | 3d | 2007-07-15 | 2007-07-18 | 131, 132 | 41.5d |  |  |  |  |
| 138 | 1.1.2.1.9 | BRUÑAS 1 cm x 1 cm R=100M/DIA | 8d | 2007-07-15 | 2007-07-23 | 132 | 34.5d | 0d |  |  |  |

| ID | WBS | Task | Duration | Start | Finish | Predecessors | Total slack | Free slack | Resources | Work | Cost | Baseline cost |
| --- | --- | --- | --- | --- | --- | --- | --- | --- | --- | --- | --- | --- |
| 139 | 1.1.2.2 | **02.00 CIELORRASOS** | 6d | 2007-07-02 | 2007-07-08 |  | 12.5d |  | CAPATAZ [0.2 H.H]; OPERARIO [2 H.H]; OFICIAL [2 H.H]; PEON [4 H.H]; OPERADOR DE EQUIPO LIVIANO [1 H.H.]; ARENA GRUESA [40.98 m3]; CEMENTO PORTLAND TIPO I (42.5 kg) [328.01 bol]; AGUA [81.04 m3]; MADERA PARA REGLAS (CEDRO) [19.29 p2]; HERRAMIENTAS MANUALES [171.26 x1.00]; MEZCLADORA DE CONCRETO TOLVA 9P3 [1 HM.] | 1263.74h | 75,676.81 | 9,471.31 |
| 140 | 1.1.2.2.1 | CIELORRASOS CON MEZCLA C:A 1:4 CON CINTAS E=1.5CM | 6d | 2007-07-02 | 2007-07-08 | 83FS+10d | 12.5d | 0d | CAPATAZ [1.02 H.H]; OPERARIO [10.24 H.H]; PEON [3.84 H.H]; ARENA FINA [16.32 m3]; CEMENTO PORTLAND TIPO I (42.5 kg) [284.7 bol]; LOSETA CERAMICA DE ALTO TRANSITO .30x.30 [634.5 m2]; PORCELANA [117.83 kg]; SELLADOR DE FRAGUA [2.42 gln]; AGUA [2.42 m3]; MADERA PARA REGLAS (CEDRO) [27.19 p2]; HERRAMIENTAS MANUALES [265.46 x1.00]; VINILICO DE ALTO TRANSITO 3.2 mm [256.27 m2]; PEGAMENTO ASFALTICO PARA PISOS [14.64 gln]; OCRE [16.86 kg]; MARMOLINA (BOLSA DE 40 KG) [13.17 bol]; GRANALLA (BOLSA DE 40KG) [39.51 bol]; PLATINA DE ALUMINIO 1 X 1/8" [110.63 mL]; PULIDORA DE TERRAZO; MARMOL Y OTROS [1.02 HM.]; ARENA GRUESA [2.02 m3] | 774.14h | 57,610.57 | 19,544.64 |
| 141 | 1.1.2.3 | **03.00 PISOS Y PAVIMENTOS** | 29d | 2007-05-30 | 2007-06-28 |  | 61.5d |  |  | 349.18h | 31,979.62 |  |
| 142 | 1.1.2.3.1 | CONTRAPISO E=40mm, BASE 3cm MEZC. 1:5, ACAB. 1cm, PASTA 1:2 | 3d | 2007-06-22 | 2007-06-25 | 88 | 55.5d | 0d |  |  |  |  |
| 143 | 1.1.2.3.2 | PISO CERÁMICO DE 30x30cm COLOR ALTO TRÁNSITO S/PIEDRA R=10M2/DIA | 3d | 2007-06-25 | 2007-06-28 | 142 | 55.5d | 0d |  |  |  |  |
| 144 | 1.1.2.3.3 | PISO DE LOSETA VINILICA 30.5x30.5cm COLOR ALTO TRÁNSITO R=50M2/DIA | 3d | 2007-06-25 | 2007-06-28 | 142 | 55.5d | 0d |  |  |  |  |
| 145 | 1.1.2.3.4 | PISO DE CEMENTO PULIDO E=2" f'c 140 kg/cm2 X 4 cm 1:2 X 1 cm | 1d | 2007-06-25 | 2007-06-26 | 142 | 62.5d | 0d |  |  |  |  |
| 146 | 1.1.2.3.5 | SARDINELES DE CONCRETO f'c=210kg/cm2 REVEST. C/MAYOLICA | 1d | 2007-06-26 | 2007-06-27 | 145 | 62.5d |  | CAPATAZ [1.89 H.H]; OPERARIO [18.94 H.H]; PEON [11.36 H.H]; CLAVO PARA CEMENTO DE 1" [6.14 kg]; ZOCALO DE MADERA CEDRO 4"x3/4" [126.48 mL]; RODON DE MADERA CEDRO 1" [126.48 mL]; BARNIZ MARINO [1.23 gln]; ARENA FINA [1.1 m3]; CEMENTO PORTLAND TIPO I (42.5 kg) [7.03 bol]; CONTRAZOCALO CERAMICO .10x.30 [168.75 mL]; AGUA [1.85 m3]; IMPERMEABILIZANTE [3.47 kg]; HERRAMIENTAS MANUALES [53.07 x1.00] | 257.58h | 7,242.94 | 4,689.3 |
| 147 | 1.1.2.3.6 | **VEREDAS DE CONCRETO** | 3d | 2007-05-30 | 2007-06-02 |  | 85.5d |  | CAPATAZ [0.2 H.H]; OPERARIO [2 H.H]; PEON [1 H.H]; ARENA FINA [10.59 m3]; CEMENTO PORTLAND TIPO I (42.5 kg) [94.26 bol]; LOSETA CERAM.SERIE AMERICA SATINADO 30 X30 O SIMILAR [529.26 m2]; CEMENTO BLANCO BOLSA 50 kg [1.97 bol]; PORCELANA [98.29 kg]; SELLADOR DE FRAGUA [2.02 gln]; HERRAMIENTAS MANUALES [310.8 x1.00]; AGUA [2.02 m3] | 91.6h | 24,736.68 | 1,543.77 |
| 148 | 1.1.2.3.6.1 | EXCAVACION MANUAL A NIVEL DE SUBRASANTE EN VEREDAS | 1d | 2007-05-30 | 2007-05-31 | 121 | 85.5d | 0d |  |  |  |  |
| 149 | 1.1.2.3.6.2 | EXCAVACION MANUAL PARA SARDINEL SUMERGIDO (0.15x0.30M) | 0.5d | 2007-05-31 | 2007-05-31 | 148 | 87.5d | 0d |  |  |  |  |
| 150 | 1.1.2.3.6.3 | ELIMINACION DE MATERIAL EXCEDENTE CON MÁQUINA V=40KPH D=30 km | 0.5d | 2007-06-01 | 2007-06-01 | 149 | 87.5d | 0d |  |  |  |  |
| 151 | 1.1.2.3.6.4 | CONFORMACIÓN Y COMPACTACIÓN DE SUBRASANTE C/RODILLO LISO MANUAL | 0.5d | 2007-06-01 | 2007-06-01 | 150 | 87.5d | 0d | CAPATAZ [0.1 H.H]; OPERARIO [1 H.H]; PEON [0.5 H.H]; ARENA FINA [0.1 m3]; CEMENTO PORTLAND TIPO I (42.5 kg) [1.25 bol]; AGUA [0.05 m3]; MADERA PARA REGLAS (CEDRO) [0.14 p2]; HERRAMIENTAS MANUALES [2.06 x1.00] | 6.4h | 127.35 |  |
| 152 | 1.1.2.3.6.5 | BASE GRANULAR E=0.10M COMPACTADO C/COMPACTADOR LISO MANUAL | 0.5d | 2007-06-02 | 2007-06-02 | 151 | 87.5d |  | CAPATAZ [0.1 H.H]; OPERARIO [1 H.H]; PEON [1 H.H]; ARENA FINA [0.2 m3]; CEMENTO PORTLAND TIPO I (42.5 kg) [2.5 bol]; AGUA [0.05 m3]; MADERA PARA REGLAS (CEDRO) [0.13 p2]; HERRAMIENTAS MANUALES [3.08 x1.00] | 8.4h | 192.04 |  |
| 153 | 1.1.2.3.6.6 | ENCOFRADO Y DESENCOFRADO EN SARDINEL DE VEREDAS H=0.30M | 0.5d | 2007-05-31 | 2007-05-31 | 148 | 85.5d | 0d |  |  |  |  |
| 154 | 1.1.2.3.6.7 | VEREDA DE CONCRETO f`c=175Kg/cm2 DE 4" ACABADO 4:2 INCL. BRUÑADO Y CURADO S/ENCOFR. | 0.5d | 2007-06-01 | 2007-06-01 | 153 | 87d | 0d |  |  |  |  |
| 155 | 1.1.2.3.6.8 | CONCRETO f'c= 175kg/cm2 PARA SARDINEL | 0.5d | 2007-06-01 | 2007-06-01 | 153 | 85.5d | 0d |  |  |  |  |
| 156 | 1.1.2.3.7 | JUNTAS ASFALTICAS E=1" | 0.5d | 2007-06-01 | 2007-06-01 | 154 | 87d | 0d |  |  |  |  |
| 157 | 1.1.2.4 | **04.00 CONTRAZOCALOS** | 33d | 2007-06-01 | 2007-07-04 |  | 55.5d |  | CAPATAZ [1.14 H.H]; OPERARIO [4.55 H.H]; OFICIAL [4.55 H.H]; CLAVOS CON CABEZA PROMEDIO [11.51 kg]; TORNILLO AVELLANADO [878.8 und]; MATERIALES DIVERSOS [418.01 x1.00]; LIJA PARA MADERA [188.93 hja]; VIDRIO TRIPLE E=6mm [349.67 p2]; LAMINA PLASTICO e=0.07mm (1.22 x 2.44 m.) [177.49 pln]; AGLOMERADO MDF E=5.5mm. (.80m. x 2.60m.) [58.8 pln]; COLA SINTETICA [17.66 gln]; PEGAMENTO PARA FORMICA (1/4 gln.) [28.83 und]; MADERA CEDRO [1961.99 p2]; ANGULO DE FIERRO NEGRO DE 1 1/2" X 1 1/2" X 1/8" X 6m [29.55 pza]; PLANCHA DE ACERO INOXIDABLE SEMI MATE 1/32" [124.02 m2]; HERRAMIENTAS MANUALES [361.61 x1.00]; CEPILLADORA ELECTRICA [0.91 HM.]; SIERRA CIRCULAR [0.91 HM.]; EQUIPO DE CORTE [0.68 HM.]; TRIPLAY DE 4´x 8´x 4mm. [0.86 pln]; PLANCHA DE PLOMO (1/16" x 1.20 x 2.50m. ) [2.29 pln] | 3711.22h | 91,993.03 | 5,453.42 |
| 158 | 1.1.2.4.1 | CONTRAZOCALO DE CERÁMICA COLOR 10 X 30 cm H=0.10m R=30M2/DIA | 6d | 2007-06-28 | 2007-07-04 | 143 | 55.5d |  |  |  |  |  |
| 159 | 1.1.2.4.2 | CONTRAZOCALO DE CEDRO DE 3/4" X 4" RODON 3/4" H=3/4" R=80M/DIA | 6d | 2007-06-28 | 2007-07-04 | 144 | 55.5d |  | CAPATAZ [0.1 H.H]; OPERARIO [1 H.H]; OFICIAL [0.5 H.H]; GARRUCHAS DE 3" [2 und]; LIJA PARA FIERRO [44.38 hja]; SOLDADURA CELLOCORD TIPO 6011 [28.69 kg]; ANGULAR DE 1"x1"x3/16"x6M. [22.26 pza]; PLATINA DE ACERO 1/4" X 1 1/2" X 6 m [0.78 pza]; PLATINA DE F.N. 1/ 4" X 2"X 6 m [7 pza]; PLANCHA DE ACERO e= 1/16" [0.01 pza]; BARRA DE FIERRO REDONDO LISO 1/2"x6m [0.18 pza]; TUBO DE FIERRO NEGRO 2"x2"x 3/16" [3.52 pza]; BISAGRA DE FIERRO DE 5" [4.01 und]; WAYPE [2.6 kg]; ANGULAR DE FIERRO NEGRO DE 1"x1"x1/8" [8.67 pza]; PLATINA DE FIERRO DE 3/4"x1/8"x6m [84.5 pza]; PINTURA ESMALTE [2.6 gln]; PINTURA ANTICORROSIVA [2.6 gln]; AGUARRAS [3.9 gln]; HERRAMIENTAS MANUALES [84.72 x1.00]; EQUIPO DE SOLDEO [0.15 HM.]; PEON [0.1 H.H] | 88.8h | 4,804.1 |  |
| 160 | 1.1.2.4.3 | CONTRAZOCALO CEMENTO SIN COLOREAR H = 10 cm PULIDO R=60M/DIA | 3d | 2007-06-01 | 2007-06-04 | 155 | 85.5d |  | CAPATAZ [0.1 H.H]; OPERARIO [1 H.H]; PEON [0.5 H.H]; LIJA PARA FIERRO [4.68 hja]; SOLDADURA CELLOCORD TIPO 6011 [2.81 kg]; TUBO DE FºGº 1" [18.7 mL]; TUBO DE FºGº 1 1/2" [19.64 mL]; HERRAMIENTAS MANUALES [11.53 x1.00]; EQUIPO DE CORTE Y SOLDEO [0.5 HM.] | 50.4h | 1,222.72 |  |
| 161 | 1.1.2.4.4 | CONTRAZOCALO DE TERRAZO PULIDO H=0.10 M | 3d | 2007-07-01 | 2007-07-04 | 166 | 55.5d |  | CAPATAZ [0.38 H.H]; OPERARIO [3.78 H.H]; PEON [3.78 H.H]; LIJA PARA FIERRO [34.02 hja]; SOLDADURA CELLOCORD TIPO 6011 [2.84 kg]; PLATINA DE FIERRO DE 1/2" [22.68 mL]; TUBO DE FºGº 1 1/2" [113.4 mL]; HERRAMIENTAS MANUALES [88.68 x1.00]; EQUIPO DE CORTE Y SOLDEO [0.76 HM.] | 208.66h | 5,088.75 |  |
| 162 | 1.1.2.5 | **05.00 ZOCALOS** | 6d | 2007-07-23 | 2007-07-29 |  | 30.5d |  | CAPATAZ [0.1 H.H]; OPERARIO [1 H.H]; PEON [1 H.H]; LIJA PARA FIERRO [15.68 hja]; SOLDADURA CELLOCORD TIPO 6011 [1.88 kg]; PINTURA ESMALTE [0.21 gln]; TUBO DE FºGº 1 1/2" [100.32 mL]; PINTURA ZINCROMATO [0.21 gln]; HERRAMIENTAS MANUALES [16.34 x1.00]; EQUIPO DE CORTE Y SOLDEO [0.1 HM.] | 206.4h | 4,113.16 |  |
| 163 | 1.1.2.5.1 | ZOCALO DE CERAMICO DE 30 x 30 CM COLOR H=<1.50 | 6d | 2007-07-23 | 2007-07-29 | 130 | 30.5d |  | CAPATAZ [0.1 H.H]; OPERARIO [1 H.H]; PEON [1 H.H]; TAPA DE FIERRO DE 0.70x0.70 M (INST. SANITARIA) [1 und]; PINTURA EPOXICA [0.05 gln]; HERRAMIENTAS MANUALES [0.94 x1.00] | 100.8h | 1,005.11 |  |
| 164 | 1.1.2.5.2 | ZOCALO DE CERAMICO DE 30 x 30 CM COLOR H>1.50M | 6d | 2007-07-23 | 2007-07-29 | 130 | 30.5d |  |  |  |  | 2,094.1 |

| ID | WBS | Task | Duration | Start | Finish | Predecessors | Total slack | Free slack | Constraint | Resources | Work | Cost | Baseline cost |
| --- | --- | --- | --- | --- | --- | --- | --- | --- | --- | --- | --- | --- | --- |
| 165 | 1.1.2.6 | **06.00 REVESTIMIENTOS DE GRADAS Y ESCALERAS** | 6d | 2007-06-28 | 2007-07-04 |  | 55.5d |  |  | CAPATAZ [0.68 H.H]; OPERARIO [6.83 H.H]; CERRADURA TIPO A [1 und]; CERRADURA TIPO B [19 und]; CERRADURA TIPO C [2 und]; CERRADURA TIPO D [15 und]; CERRADURA TIPO E [2 und]; CERRADURA TIPO F [5 und]; BRAZO HIDRAULICO TIPO G [17 jgo]; CERRADURA TIPO H [15 und]; PICAPORTE TIPO J [1 jgo]; TOPE DE PUERTA TIPO K [28 und]; CERRADURA TIPO L [3 und]; HERRAMIENTAS MANUALES [61.07 x1.00]; PEON [1.02 H.H] | 471.55h | 12,195.34 |  |
| 166 | 1.1.2.6.1 | REVESTIMIENTO DE GRADAS Y ESCALERAS CON TERRAZO R=15M/DIA | 3d | 2007-06-28 | 2007-07-01 | 102 | 55.5d | 0d |  |  |  |  |  |
| 167 | 1.1.2.6.2 | REVESTIMIENTO DE DESCANSOS CON TERRAZO | 3d | 2007-07-01 | 2007-07-04 | 166 | 55.5d |  |  | CAPATAZ [0.23 H.H]; OPERARIO [2.35 H.H]; BISAGRA ALUMINIZADA DE 4"x4" [147 und]; BISAGRA ALUMINIZADA DE 2"x2" [2 und]; BISAGRA VAI VEN DE 4" [75 und]; HERRAMIENTAS MANUALES [19.06 x1.00]; BISAGRA DE ACERO REVESTIDA EN PLOMO DE 4"x4" [9 und] | 61.95h | 2,127.86 |  |
| 168 | 1.1.2.7 | **07.00 CUBIERTAS** | 2d | 2007-07-22 | 2007-07-24 |  | 35.5d |  |  |  | 422.69h | 14,073.06 |  |
| 169 | 1.1.2.7.1 | CUBIERTA LADRILLO PASTELERO ASENTADO CON MORTERO 1:5 | 1d | 2007-07-23 | 2007-07-24 | 138 | 34.5d | 0d |  | CAPATAZ [2.52 H.H]; OPERARIO [25.16 H.H]; PEON [25.16 H.H]; VIDRIO TRIPLE E=6mm [2214.5 p2]; HERRAMIENTAS MANUALES [118.07 x1.00] | 422.69h | 14,073.06 |  |
| 170 | 1.1.2.7.2 | COBERTURA DE POLICARBONATO C/SOPORTE DE ACERO | 1d | 2007-07-22 | 2007-07-23 | 226 | 36.5d |  |  |  |  |  |  |
| 171 | 1.1.2.8 | **08.00 CARPINTERIA DE MADERA** | 79.5d? | 2007-05-01 | 2007-07-19 |  | 38.5d | 0d |  |  | 2112.92h | 39,439.14 |  |
| 172 | 1.1.2.8.1 | PUERTA P-1, 1.00x2.60, DE 56.1 mm CONTRAPLACADA C/MELAMINA E=9MM | 7d | 2007-07-12 | 2007-07-19 | 131, 125 | 38.5d |  |  | CAPATAZ [0.1 H.H]; OPERARIO [1 H.H]; PEON [1 H.H]; ESPEJO CRISTAL 6MM [21.1 p2]; SILICONA [0.49 und]; HERRAMIENTAS MANUALES [1.31 x1.00] | 117.6h | 1,259.47 |  |
| 174 | 1.1.2.8.2 | PUERTA P-2, 0.90x1.10, DE 56.1 mm CONTRAPLACADA C/MELAMINA E=9MM | 7d | 2007-07-12 | 2007-07-19 | 131, 125 | 38.5d |  |  |  |  |  |  |
| 175 | 1.1.2.8.3 | PUERTA P-3, 1.20x2.10, DE 56.1 mm CONTRAPLACADA C/MELAMINA E=9MM | 7d | 2007-07-12 | 2007-07-19 | 131, 125 | 38.5d |  |  | CAPATAZ [1.16 H.H]; OPERARIO [11.57 H.H]; PEON [6.71 H.H]; LIJA PARA MADERA [609.12 hja]; IMPRIMANTE [109.64 gln]; PINTURA LATEX SINTETICO [14.45 gln]; PINTURA LATEX POLIVINILICO [120.96 gln]; PINTURA LATEX ACRILICO [25.44 gln]; HERRAMIENTAS MANUALES [311.49 x1.00]; ANDAMIO METALICO [5.78 HM.] | 1412.12h | 24,135.03 | 4,743.96 |
| 176 | 1.1.2.8.4 | PUERTA P-4, 0.80x1.75, DE 56.1 mm CONTRAPLACADA C/MELAMINA E=9MM | 7d | 2007-07-12 | 2007-07-19 | 131, 125 | 38.5d |  |  | CAPATAZ [0.1 H.H]; OPERARIO [1 H.H]; PEON [0.5 H.H]; LIJA PARA FIERRO [15.5 hja]; PINTURA ESMALTE [1.55 gln]; AGUARRAS [0.15 gln]; PINTURA ZINCROMATO [1.55 gln]; HERRAMIENTAS MANUALES [7.64 x1.00] | 89.6h | 1,147.46 | 3,881.91 |
| 177 | 1.1.2.8.5 | PUERTA P-5, 1.20x2.60, DE 56.1 mm CONTRAPLACADA C/MELAMINA E=9MM | 7d | 2007-07-12 | 2007-07-19 | 131, 125 | 38.5d |  |  | CAPATAZ [0.43 H.H]; OPERARIO [4.29 H.H]; PEON [2.79 H.H]; LIJA PARA MADERA [212.1 hja]; THINNER ACRILICO [1.64 gln]; LACA SELLADORA P/MADERA [7.22 gln]; LACA ACRILICA [4.32 gln]; PINTURA LATEX ECONOMICO [19.31 gln]; AGUARRAS [2.85 gln]; BARNIZ MARINO [6.5 gln]; BARNIZ SELLADOR PARA MADERA [10.88 gln]; HERRAMIENTAS MANUALES [119.04 x1.00]; ANDAMIO METALICO [0.86 HM.]; PRESERVANTE PARA MADERA [29.88 gln] | 468h | 8,697.59 | 554.08 |
| 178 | 1.1.2.8.6 | PUERTA P-6, 0.80x2.60, DE 56.1 mm CONTRAPLACADA C/MELAMINA E=9MM | 7d | 2007-07-12 | 2007-07-19 | 131, 125 | 38.5d |  |  |  |  |  |  |
| 179 | 1.1.2.8.7 | PUERTA P-7, 1.20x2.75, DE 56.1 mm CONTRAPLACADA C/MELAMINA E=9MM | 7d | 2007-07-12 | 2007-07-19 | 131, 125 | 38.5d |  |  |  |  |  |  |
| 180 | 1.1.2.8.8 | PUERTA P-8, 0.90x2.10, DE 56.1 mm CONTRAPLACADA C/MELAMINA E=9MM | 7d | 2007-07-12 | 2007-07-19 | 131, 125 | 38.5d |  | start no earlier than 2006-11-13 | LETRERO LOGOTIPO PINTADO EN MURO [1 und]; CAPATAZ [0.1 H.H]; OPERARIO [1 H.H]; PEON [0.5 H.H]; SEÑAL INDICATIVA C/ACRILICO Y MARCO MAD.ADOSADO PARED [8 und]; SEÑAL ORIENTATIVA ACRILICO ADOSADA [65 und]; HERRAMIENTAS MANUALES [17.6 x1.00] | 25.6h | 4,199.58 |  |
| 181 | 1.1.2.8.9 | PUERTA P-9, 1.00x2.10, DE 56.1 mm CONTRAPLACADA C/MELAMINA E=9MM | 7d | 2007-07-12 | 2007-07-19 | 131, 125 | 32.5d | 0d |  |  |  |  |  |
| 182 | 1.1.2.9 | **09.00 CARPINTERIA METALICA** | 16d | 2007-07-19 | 2007-08-04 |  | 24.5d |  |  |  |  |  |  |
| 183 | 1.1.2.9.1 | PUERTA ENROLLABLE PE-1 2.90x2.65M | 2d | 2007-07-19 | 2007-07-21 | 224 | 38.5d |  |  |  |  |  |  |
| 184 | 1.1.2.9.2 | PUERTA DE REJA METÁLICA PR-1 | 1d | 2007-07-19 | 2007-07-20 | 224 | 39.5d |  |  |  |  |  |  |
| 185 | 1.1.2.9.3 | PUERTA DE REJA METÁLICA PR-2 | 1d | 2007-07-19 | 2007-07-20 | 224 | 39.5d |  |  |  |  |  |  |
| 186 | 1.1.2.9.4 | VENTANA TIPO REJA | 3d | 2007-07-19 | 2007-07-22 | 224 | 31.5d | 0d |  |  |  |  |  |
| 187 | 1.1.2.9.5 | ESCALERA DE GATO TUBO Fº Gº CON PARANTES DE 1 1/2" X PELDAÑOS DE 1" | 1d | 2007-07-24 | 2007-07-25 | 186, 169 | 34.5d |  |  |  |  |  |  |
| 188 | 1.1.2.9.6 | PASAMANOS DE TUBO FIERRO GALVANIZADO 1 1/2" - EN ESCALERA | 3d | 2007-07-22 | 2007-07-25 | 186 | 31.5d | 0d |  |  |  |  |  |
| 189 | 1.1.2.9.7 | BARANDA DE TUBO FIERRO GALVANIZADO PASAMANO 1 1/2" - PARANTE 1 1/2" H=0.90 m | 1d | 2007-07-25 | 2007-07-26 | 188 | 31.5d | 0d |  |  |  |  |  |
| 190 | 1.1.2.9.8 | BARANDA DE TUBO FIERRO GALVANIZADO PASAMANO 1 1/2" - PARANTE 1 1/2" H=1.5 m | 1d | 2007-07-26 | 2007-07-27 | 189 | 31.5d | 0d |  |  |  |  |  |
| 191 | 1.1.2.9.9 | TAPA METÁLICA PARA CISTERNA | 1d | 2007-07-27 | 2007-07-28 | 190 | 31.5d |  |  |  |  |  |  |
| 192 | 1.1.2.9.10 | TAPAJUNTA METÁLICA 1/4" x 6" | 1d | 2007-07-29 | 2007-07-30 | 144, 227 | 29.5d |  |  |  |  |  |  |
| 193 | 1.1.2.9.11 | TAPAJUNTA METÁLICA 4" x 4" x 1/4" | 1d | 2007-07-22 | 2007-07-23 | 224, 226 | 36.5d |  |  |  |  |  |  |
| 194 | 1.1.2.9.12 | PROTECTOR DE VENTANAS | 3d | 2007-08-01 | 2007-08-04 | 196 | 24.5d |  |  |  |  |  |  |
| 195 | 1.1.2.9.13 | MALLA METÁLICA PROTECTORA C/ALAMBRE Nº 8 COCADA 2"x2" | 1d | 2007-07-26 | 2007-07-27 | 189 | 32.5d |  |  |  |  |  |  |

| ID | WBS | Task | Duration | Start | Finish | Predecessors | Total slack | Free slack |
| --- | --- | --- | --- | --- | --- | --- | --- | --- |
| 196 | 1.1.2.10 | **10.00 CARPINTERIA DE ALUMINIO** | 3d | 2007-07-29 | 2007-08-01 |  | 24.5d | 0d |
| 197 | 1.1.2.10.1 | VENTANA V-15 DE 1.20x1.60m DE ALUMINIO SEGUN DETALLE | 1d | 2007-07-29 | 2007-07-30 | 227 | 26.5d |  |
| 198 | 1.1.2.10.2 | VENTANA V-17 DE 1.20x0.70m DE ALUMINIO SEGUN DETALLE | 3d | 2007-07-29 | 2007-08-01 | 227 | 24.5d |  |
| 199 | 1.1.2.10.3 | VENTANA V-17' DE 1.05x0.70m DE ALUMINIO SEGUN DETALLE | 1d | 2007-07-29 | 2007-07-30 | 227 | 26.5d |  |
| 200 | 1.1.2.10.4 | VENTANA V-18 DE 3.05x0.95m DE ALUMINIO SEGUN DETALLE | 1d | 2007-07-29 | 2007-07-30 | 227 | 26.5d |  |
| 201 | 1.1.2.10.5 | VENTANA V-19 DE 0.60x1.00m DE ALUMINIO SEGUN DETALLE | 1d | 2007-07-29 | 2007-07-30 | 227 | 26.5d |  |
| 202 | 1.1.2.10.6 | VENTANA V-21 DE 1.80x1.90m DE ALUMINIO SEGUN DETALLE | 1d | 2007-07-29 | 2007-07-30 | 227 | 26.5d |  |
| 203 | 1.1.2.10.7 | VENTANA V-22 DE 3.175x0.75m DE ALUMINIO SEGUN DETALLE | 1d | 2007-07-29 | 2007-07-30 | 227 | 26.5d |  |
| 204 | 1.1.2.10.8 | VENTANA V-22' DE 1.45x0.75m DE ALUMINIO SEGUN DETALLE | 1d | 2007-07-29 | 2007-07-30 | 227 | 26.5d |  |
| 205 | 1.1.2.10.9 | VENTANA V-23 DE 3.65x0.60m DE ALUMINIO SEGUN DETALLE | 1d | 2007-07-29 | 2007-07-30 | 227 | 26.5d |  |
| 206 | 1.1.2.11 | **11.00 CERRAJERIA** | 5d | 2007-07-18 | 2007-07-23 |  | 36.5d |  |
| 207 | 1.1.2.11.1 | CERRADURA TIPO A CON 2 MANIJAS, CON LLAVE INT/EXT | 1d | 2007-07-19 | 2007-07-20 | 171 | 39.5d |  |
| 208 | 1.1.2.11.2 | CERRADURA TIPO B CON 2 MANIJAS C/SEGURO INT. Y LLAVE EXT. | 1d | 2007-07-19 | 2007-07-20 | 171 | 39.5d |  |
| 209 | 1.1.2.11.3 | CERRADURA TIPO C CON 2 MANIJAS, LLAVE EXTERIOR Y ALETA DE SEGURIDAD INTERIOR | 2d | 2007-07-19 | 2007-07-21 | 171 | 38.5d |  |
| 210 | 1.1.2.11.4 | CERRADURA TIPO D CON TIRADORES INT/EXT, VAIVEN DE PASE | 1d | 2007-07-19 | 2007-07-20 | 171 | 39.5d |  |
| 211 | 1.1.2.11.5 | CERRADURA TIPO E, DE SOBREPONER TIPO PARCHE | 1d | 2007-07-19 | 2007-07-20 | 171 | 39.5d |  |
| 212 | 1.1.2.11.6 | CERRADURA TIPO F, C/PICAPORTE DE 2 1/2" | 1d | 2007-07-19 | 2007-07-20 | 171 | 39.5d |  |
| 213 | 1.1.2.11.7 | TOPE DE PUERTA EN PARED | 1d | 2007-07-19 | 2007-07-20 | 171 | 39.5d |  |
| 214 | 1.1.2.11.8 | TOPE DE PUERTA EN PISO ACERO | 1d | 2007-07-19 | 2007-07-20 | 171 | 39.5d |  |
| 215 | 1.1.2.11.9 | FRENO HIDRÁULICO | 1d | 2007-07-22 | 2007-07-23 | 220FF | 36.5d |  |
| 216 | 1.1.2.11.10 | BISAGRA ALUMINIZADA CAPUCHINA DE 4" X 4" | 1d | 2007-07-18 | 2007-07-19 | 171FF | 40.5d |  |
| 217 | 1.1.2.12 | **12.00 VIDRIOS, CRISTALES Y SIMILARES** | 46d | 2007-06-08 | 2007-07-24 |  | 35.5d |  |
| 218 | 1.1.2.12.1 | VIDRIOS DOBLES TRANSPARENTES 4MM | 2d | 2007-07-22 | 2007-07-24 | 226 | 35.5d |  |
| 219 | 1.1.2.12.2 | BLOCKS DE VIDRIO DE 19x19x8cm | 2d | 2007-06-08 | 2007-06-10 | 63SS+7d | 79.5d |  |
| 220 | 1.1.2.12.3 | PUERTA Pb-1 PIVOTANTE 2.60x1.95m CRISTAL TEMPLADO BRONCE DE 10MM | 1d | 2007-07-22 | 2007-07-23 | 226 | 36.5d | 0d |
| 221 | 1.1.2.12.4 | VENTANA ATENCIÓN V-6 2.75x0.80m CRISTAL TEMPLADO BRONCE DE 10MM C/DISPENSADOR | 1d | 2007-07-22 | 2007-07-23 | 226 | 36.5d |  |
| 222 | 1.1.2.12.5 | ESPEJOS BISELADOS DE 50X60CM E=6MM | 1d | 2007-07-22 | 2007-07-23 | 226 | 36.5d |  |

| ID | WBS | Task | Duration | Start | Finish | Predecessors | Total slack | Free slack |
| --- | --- | --- | --- | --- | --- | --- | --- | --- |
| 223 | 1.1.2.13 | **13.00 PINTURA** | 16d | 2007-07-13 | 2007-07-29 |  | 16.5d |  |
| 224 | 1.1.2.13.1 | PINTADO DE MURO INTERIOR EXISTENTE CON LATEX VINILICO (VINILATEX O SIMILAR) | 2d | 2007-07-17 | 2007-07-19 | 131FS+5d | 31.5d | 0d |
| 225 | 1.1.2.13.2 | PINTADO DE MURO EXTERIOR EXISTENTE CON LATEX ACRÍLICO | 1d | 2007-07-24 | 2007-07-25 | 224FS+5d | 34.5d |  |
| 226 | 1.1.2.13.3 | PINTADO DE MURO INTERIOR NUEVO CON LATEX VINILICO (VINILATEX O SIMILAR) | 5d | 2007-07-17 | 2007-07-22 | 131FS+5d | 12.5d | 0d |
| 227 | 1.1.2.13.4 | PINTADO DE MURO EXTERIOR NUEVO CON LATEX ACRILICO (SUPERLATEX O SIMILAR) | 2d | 2007-07-27 | 2007-07-29 | 226FS+5d | 24.5d | 0d |
| 228 | 1.1.2.13.5 | PINTADO DE CIELO RASO EXISTENTE CON LATEX VINILICO (VINILATEX O SIMILAR) | 6d | 2007-07-13 | 2007-07-19 | 140FS+5d | 40.5d |  |
| 229 | 1.1.2.13.6 | PINTADO DE CIELO RASO NUEVO CON LATEX VINILICO (VINILATEX O SIMILAR) | 1d | 2007-07-17 | 2007-07-18 | 131FS+5d | 41.5d |  |
| 230 | 1.1.2.13.7 | PINTURA MARCOS PUERTAS MELAMÍNICAS C/LACA 2 MANOS | 3d | 2007-07-24 | 2007-07-27 | 181FS+5d | 32.5d |  |
| 231 | 1.1.2.14 | **14.00 JUNTAS** | 27d | 2007-06-01 | 2007-06-28 |  | 61.5d |  |
| 232 | 1.1.2.14.1 | ENCUENTRO DE PISOS INTERIORES | 1d | 2007-06-27 | 2007-06-28 | 143FF, 144FF | 61.5d |  |
| 233 | 1.1.2.14.2 | JUNTAS ASFALTICAS E=1" | 1d | 2007-06-02 | 2007-06-02 | 156 | 87d |  |
| 234 | 1.1.2.14.3 | JUNTA DE DILATACIÓN CON TEKNOPORT E=1" C/ACABADO DE SELLANTE ASFALTICO | 12d | 2007-06-01 | 2007-06-13 | 64 | 76.5d |  |
| 235 | 1.1.2.14.4 | JUNTA DE DILATACIÓN CON TEKNOPORT E=2" | 3d | 2007-06-01 | 2007-06-04 | 64 | 85.5d |  |
| 236 | 1.1.2.15 | **15.00 SEÑALÉTICA** | 3d | 2007-08-01 | 2007-08-04 |  | 24.5d |  |
| 237 | 1.1.2.15.1 | PINTADO LOGO INSTITUCIONAL 3.20 X 0.75 m | 1d | 2007-08-01 | 2007-08-02 | 196, 226 | 26.5d |  |
| 238 | 1.1.2.15.2 | SALIDAS DE DIRECCIÓN O EMERGENCIA 0.25x0.40m PLACA TIPO BANDERA | 2d | 2007-08-01 | 2007-08-03 | 196, 226 | 25.5d |  |
| 239 | 1.1.2.15.3 | SEÑAL INDICATIVA 1.60 x 0.30m PLACA COLGANTE | 1d | 2007-08-01 | 2007-08-02 | 196, 226 | 26.5d |  |
| 240 | 1.1.2.15.4 | SEÑAL INDICATIVA 0.25 x 0.40m PLACA EN PARED | 3d | 2007-08-01 | 2007-08-04 | 196, 226 | 24.5d |  |
| 241 | 1.1.2.15.5 | SEÑAL INDICATIVA 0.25 x 0.40m PLACA TIPO BANDERA | 1d | 2007-08-01 | 2007-08-02 | 196, 226 | 26.5d |  |
| 242 | 1.1.2.15.6 | SEÑAL INDICATIVA 0.30 x 0.40m PLACA TIPO BANDERA | 1d | 2007-08-01 | 2007-08-02 | 196, 226 | 25.5d | 0d |
| 243 | 1.1.2.15.7 | **SEÑALES PARA PLANES DE CONTINGENCIA Y EVACUACION** | 1d | 2007-08-02 | 2007-08-03 |  | 25.5d |  |
| 244 | 1.1.2.15.7.1 | SEÑAL ADOSADA | 1d | 2007-08-02 | 2007-08-03 | 242 | 25.5d |  |
| 245 | 1.1.2.15.7.2 | SEÑAL DE SEGURIDAD EXTERNA - PINTADO EN PISO | 1d | 2007-08-02 | 2007-08-03 | 242 | 25.5d |  |
| 246 | 1.1.2.16 | **16.00 VARIOS** | 97d | 2007-05-24 | 2007-08-28 |  | 0d |  |
| 247 | 1.1.2.16.1 | TABIQUE DRY WALL C/PLANCHA FIBROCEMENTO E=0.11M | 1d | 2007-07-12 | 2007-07-13 | 131 | 46.5d |  |
| 248 | 1.1.2.16.2 | PANEL TERMO ACÚSTICO TIPO FIBER WALL E=2" | 1d | 2007-06-26 | 2007-06-27 | 145 | 62.5d |  |
| 249 | 1.1.2.16.3 | LIMPIEZA PERMANENTE DE OBRA | 97d | 2007-05-24 | 2007-08-28 | 48 | 0d |  |

| ID | WBS | Task | Duration | Start | Finish | Predecessors | Total slack | Free slack | Resources | Work | Cost | Baseline cost |
| --- | --- | --- | --- | --- | --- | --- | --- | --- | --- | --- | --- | --- |
| 250 | 1.1.3 | **INSTALACIONES SANITARIAS** | 73.5d | 2007-05-24 | 2007-08-05 |  | 23.5d |  |  | 869.71h | 29,565.32 |  |
| 251 | 1.1.3.1 | **1.00 TRABAJOS PRELIMINARES - MOV. TIERRAS** | 0.5d | 2007-05-24 | 2007-05-24 |  | 88.5d |  |  | 24.4h | 508.41 |  |
| 252 | 1.1.3.1.1 | TRAZO Y REPLANTEO REDES AGUA Y DESAGUE | 0.5d | 2007-05-24 | 2007-05-24 | 48 | 88.5d | 0d | CAPATAZ [0.1 H.H]; PEON [3 H.H]; TOPOGRAFO [1 H.H]; CLAVOS CON CABEZA PROMEDIO [2.78 kg]; YESO BOLSA DE 20 Kg [9.27 bol]; CORDEL [74.14 mL]; MADERA TORNILLO [7.41 p2]; HERRAMIENTAS MANUALES [10.03 x1.00]; TEODOLITO [0.5 HM.]; NIVEL [0.5 HM.]; JALON [0.5 HM.]; MIRA [0.5 HM.] | 24.4h | 508.41 | 2,371.5 |
| 253 | 1.1.3.2 | **2.00 MOVIMIENTO DE TIERRAS** | 2.5d | 2007-05-24 | 2007-05-26 |  | 88.5d |  | CAPATAZ [0.44 H.H]; PEON [4 H.H]; ARENA GRUESA [2.91 m3]; AGUA [6.68 m3]; HERRAMIENTAS MANUALES [52.28 x1.00]; COMPACTADOR VIBRATORIO TIPO PLANCHA 4HP [0.44 HM.]; OPERARIO [0.44 H.H] | 139.05h | 5,692.47 | 1,121.62 |
| 254 | 1.1.3.2.1 | EXCAVACION DE ZANJAS | 1d | 2007-05-24 | 2007-05-25 | 252 | 88.5d | 0d |  |  |  |  |
| 255 | 1.1.3.2.2 | CAMA DE APOYO | 0.5d | 2007-05-25 | 2007-05-25 | 254 | 94d | 0d |  |  |  |  |
| 256 | 1.1.3.2.3 | RELLENO COMPACTADO | 0.5d | 2007-05-26 | 2007-05-26 | 255 | 94d | 0d |  |  |  |  |
| 257 | 1.1.3.2.4 | ELIMINACION DE MAT. EXCEDENTE C/MAQ. | 0.5d | 2007-05-26 | 2007-05-26 | 256 | 94d |  | OPERADOR DE EQUIPO PESADO [2 H.H]; CAPATAZ [0.1 H.H]; PEON [1 H.H]; HERRAMIENTAS MANUALES [0.48 x1.00]; VOLQUETE 6X4 330 HP 10M3 [4 HM.]; CARGADOR FRONTAL S/LLANTAS 125-155 HP [1 HM.] | 32.4h | 3,821.01 | 770.77 |
| 258 | 1.1.3.3 | **3.00 SISTEMA DE DESAGUE Y VENTILACION** | 7d | 2007-05-25 | 2007-06-01 |  | 88.5d |  |  | 377.06h | 13,968.99 |  |
| 259 | 1.1.3.3.1 | SALIDAS DE DESAGUE Y VENTILACION | 2d | 2007-05-25 | 2007-05-27 | 254 | 88.5d | 0d | CAPATAZ [0.85 H.H]; OPERARIO [8.46 H.H]; PEON [8.46 H.H]; LIJA PARA MADERA [7.1 hja]; PEGAMENTO PARA TUBERIA PVC [3.6 gln]; TUBERIA PVC-SAL PESADA DE 2" X 3M [41.2 pza]; CODO PVC C-5 2" X 90o (DESAGUE) [107 und]; RAMAL YEE DE PVC C-5 DE 4"x2" (DESAGUE) [47 und]; TUBERIA PVC-SAL PESADA DE 4" X 3M [7.2 pza]; CODO PVC C-5 4" X 90o (DESAGUE) [24 und]; RAMAL TEE SIMPLE PVC C-5 DE 2" (DESAGUE) [13 und]; RAMAL YEE SIMPLE PVC C-5 DE 4" (DESAGUE) [12 und]; HERRAMIENTAS MANUALES [79.38 x1.00] | 284.26h | 5,903.77 |  |
| 260 | 1.1.3.3.2 | RAMALES Y MONTANTES | 2d | 2007-05-27 | 2007-05-29 | 259 | 88.5d | 0d | CAPATAZ [0.2 H.H]; OPERARIO [2 H.H]; PEON [2 H.H]; LIJA PARA MADERA [15.87 hja]; PEGAMENTO PARA TUBERIA PVC [11.35 gln]; TUBERIA PVC-SAL PESADA DE 2" X 3M [60.92 pza]; UNION DOBLE PVC C-5 DE 2" (DESAGUE) [38.2 und]; TUBERIA PVC-SAL PESADA DE 4" X 3M [26.64 pza]; UNION DOBLE PVC C-5 DE 4" (DESAGUE) [15.22 und]; TUBERIA PVC-SAL PESADA DE 6" X 5M [9.09 pza]; UNION DOBLE PVC C-5 DE 6" (DESAGUE) [8.66 und]; HERRAMIENTAS MANUALES [98.3 x1.00] | 67.2h | 5,992.59 |  |
| 261 | 1.1.3.3.3 | ACCESORIO DE REDES | 1d | 2007-05-29 | 2007-05-30 | 260 | 88.5d | 0d |  |  |  |  |
| 262 | 1.1.3.3.4 | ADITAMIENTOS VARIOS | 1d | 2007-05-30 | 2007-05-31 | 261 | 88.5d | 0d | CAPATAZ [0.1 H.H]; OPERARIO [1 H.H]; PEGAMENTO PARA TUBERIA PVC [0.2 gln]; TUBERIA PVC-SAL PESADA DE 2" X 3M [0.66 pza]; TRAMPA P PVC C-5 DE 2" (DESAGUE) [2 und]; SUMIDERO DE BRONCE DE 2" [2 pza]; TUBERIA PVC-SAL PESADA DE 4" X 3M [4.62 pza]; CODO PVC C-5 4" X 90o (DESAGUE) [7 und]; TEE SANITARIA DOBLE PVC C-5 4" (DESAGUE) [7 und]; REGISTRO ROSCADO DE BRONCE DE 4" [14 pza]; SOMBRERO DE VENTILACION PVC DE 2" [13 und]; HERRAMIENTAS MANUALES [7.74 x1.00] | 8.8h | 698.65 |  |
| 263 | 1.1.3.3.5 | CAMARAS DE INSPECCION | 1d | 2007-05-31 | 2007-06-01 | 262 | 88.5d |  | CAPATAZ [0.1 H.H]; OPERARIO [1 H.H]; PEON [1 H.H]; ALAMBRE NEGRO RECOCIDO # 16 [1 kg]; CLAVOS CON CABEZA PROMEDIO [2 kg]; ACERO CORRUGADO FY=4200 Kg/cm2 GRADO 60 [100 kg]; ARENA FINA [0.2 m3]; ARENA GRUESA [0.2 m3]; PIEDRA CHANCADA [0.1 m3]; LADRILLO KK 18 HUECOS HECHO A MAQUINA 9X13X23 [400 und]; CEMENTO PORTLAND TIPO I (42.5 kg) [15 bol]; AGUA [0.1 m3]; MADERA TORNILLO [3 p2]; HERRAMIENTAS MANUALES [18.77 x1.00] | 16.8h | 1,373.98 |  |
| 264 | 1.1.3.4 | **4.00 SISTEMA DE AGUA FRIA** | 4d | 2007-06-17 | 2007-06-21 |  | 59.5d |  |  | 329.2h | 9,395.44 |  |
| 265 | 1.1.3.4.1 | SALIDAS DE AGUA FRIA | 2d | 2007-06-19 | 2007-06-21 | 266 | 64.5d | 0d | CAPATAZ [1.62 H.H]; OPERARIO [16.25 H.H]; PEGAMENTO PARA TUBERIA PVC [0.65 gln]; TUBERIA PVC C-10 C/R DE 1/2" X 5 m [31.2 pza]; CODO PVC AGUA CON ROSCA DE 1/2" X90o [130 pza]; TEE PVC PARA AGUA CON ROSCA DE 1/2" [65 und]; HERRAMIENTAS MANUALES [87.98 x1.00] | 286h | 4,870.55 | 1,064.13 |
| 266 | 1.1.3.4.2 | RED DE DISTRIBUCION DE AGUA FRIA TUBERIA PVC C-10 | 2d | 2007-06-17 | 2007-06-19 | 124SS+7d | 59.5d | 0d | CAPATAZ [0.1 H.H]; OPERARIO [1 H.H]; PEON [1 H.H]; PEGAMENTO PARA TUBERIA PVC [2 gln]; CINTA TEFLON [24.43 rll]; TUBERIA PVC C-10 C/R DE 1/2" X 5 m [16.68 pza]; HERRAMIENTAS MANUALES [48.25 x1.00]; PINTURA ESMALTE [1.26 gln]; TUBERIA PVC C-10 C/R DE 3/4" X 5 m [17.58 pza]; UNION PVC PARA AGUA CON ROSCA 3/4" [16.74 pza]; CODO PVC AGUA CON ROSCA DE 3/4" X90o [8.37 pza]; TEE PVC PARA AGUA CON ROSCA DE 3/4" [8.37 und]; TUBERIA PVC C-10 C/R DE 1" X 5 m [15.91 pza]; UNION PVC PARA AGUA CON ROSCA 1" [15.06 pza]; CODO PVC AGUA CON ROSCA DE 1" X90o [7.53 pza]; TEE PVC PARA AGUA CON ROSCA DE 1" [7.53 und]; TUBERIA PVC C-10 C/R DE 1 1/2" X 5 m [5.36 pza]; UNION PVC PARA AGUA CON ROSCA 1 1/2" [5.1 pza]; CODO PVC AGUA CON ROSCA DE 1 1/2" X90o [2.55 pza]; TEE PVC PARA AGUA CON ROSCA DE 1 1/2" [2.55 und]; TUBERIA PVC C-10 C/R DE 2" x 5 m [13.65 mL]; UNION PVC PARA AGUA CON ROSCA 2" [13 pza]; CODO PVC AGUA CON ROSCA DE 2" X90o [6.5 pza]; TEE PVC PARA AGUA CON ROSCA DE 2" [6.5 und] | 33.6h | 4,324.45 | 577.98 |
| 267 | 1.1.3.4.3 | VALVULAS | 2d | 2007-06-19 | 2007-06-21 | 266 | 59.5d | 36d | CAPATAZ [0.1 H.H]; OPERARIO [0.5 H.H]; ARENA GRUESA [0.67 m3]; GRIFO DE RIEGO DE 1/2" [2 und]; AGUA [0.12 m3]; CINTA TEFLON [0.4 rll]; TUBO DE FIERRO GALVANIZADO DE 1/2" X 6.40 m [0.31 pza]; CODO DE FIERRO GALVANIZADO DE 1/2" X 90o [4 und]; TUBERIA DE C.S.N. ESPIGA CAMPANA DE 4" X 1M [2 pza]; ADAPTADOR PVC SAP 1/2" [2 und]; HERRAMIENTAS MANUALES [0.3 x1.00] | 9.6h | 200.45 | 597.55 |
| 268 | 1.1.3.5 | **5.00 SISTEMA DE AGUA CALIENTE** | 7d | 2007-06-16 | 2007-06-23 |  | 57.5d |  |  |  |  |  |
| 269 | 1.1.3.5.1 | SALIDAS DE AGUA CALIENTE | 1d | 2007-06-19 | 2007-06-20 | 270 | 57.5d | 0d |  |  |  |  |
| 270 | 1.1.3.5.2 | RED DE DISTRIBUCION DE AGUA CALIENTE | 3d | 2007-06-16 | 2007-06-19 | 124SS+6d | 57.5d | 0d |  |  |  |  |
| 271 | 1.1.3.5.3 | VALVULAS | 3d | 2007-06-20 | 2007-06-23 | 269 | 57.5d | 34d |  |  |  |  |
| 272 | 1.1.3.6 | **6.00 APARATOS SANITARIOS** | 5d | 2007-07-27 | 2007-08-01 |  | 23.5d |  |  |  |  |  |
| 273 | 1.1.3.6.1 | APARATOS SANITARIOS | 1d | 2007-07-27 | 2007-07-28 | 271, 267, 226FS+5d | 23.5d | 0d |  |  |  |  |
| 274 | 1.1.3.6.2 | COLOCACION DE APARATOS SANITARIOS | 4d | 2007-07-28 | 2007-08-01 | 273 | 23.5d | 0d |  |  |  |  |

| ID | WBS | Task | Duration | Start | Finish | Predecessors | Total slack | Free slack | Resources | Work | Cost | Baseline cost |
| --- | --- | --- | --- | --- | --- | --- | --- | --- | --- | --- | --- | --- |
| 275 | 1.1.3.7 | **7.00 ACCESORIOS SANITARIOS** | 2d | 2007-08-01 | 2007-08-03 |  | 23.5d |  |  |  |  |  |
| 276 | 1.1.3.7.1 | ACCESORIOS SANITARIOS | 0.5d | 2007-08-01 | 2007-08-01 | 274 | 23.5d | 0d |  |  |  |  |
| 277 | 1.1.3.7.2 | COLOCACION DE ACCESORIOS SANITARIOS | 1.5d | 2007-08-02 | 2007-08-03 | 276 | 23.5d | 0d |  |  |  |  |
| 278 | 1.1.3.8 | **8.00 VARIOS** | 73.5d | 2007-05-24 | 2007-08-05 |  | 23.5d |  |  |  |  |  |
| 279 | 1.1.3.8.1 | LIMPIEZA Y PRUEBA HIDRAULICA- RED DE DESAGUE | 2d | 2007-08-03 | 2007-08-05 | 277, 259 | 23.5d |  |  |  |  |  |
| 280 | 1.1.3.8.2 | LIMPIEZA, DESINFECCIÓN Y PRUEBAS DE RED DE AGUA MANUAL | 2d | 2007-07-28 | 2007-07-30 | 265, 273 | 27.5d | 2d |  |  |  |  |
| 281 | 1.1.3.8.3 | LIMPIEZA Y DESINFECCIÓN DE CISTERNA Y TANQUE ELEVADO | 1d | 2007-08-02 | 2007-08-03 | 150, 124, 291 | 25.5d |  |  |  |  |  |
| 282 | 1.1.3.8.4 | NICHO PARA VÁLVULAS DE 25x20CM | 0.5d | 2007-05-24 | 2007-05-24 | 98 | 96d | 0d |  |  |  |  |
| 283 | 1.1.3.8.5 | ROMPE AGUA DE PLANCHA ACERO | 0.5d | 2007-05-24 | 2007-05-24 | 282 | 96d |  |  |  |  |  |
| 284 | 1.1.3.8.6 | REBOSE Y VENTILACIÓN DE CISTERNA | 1d | 2007-06-21 | 2007-06-22 | 97, 265 | 66.5d | 0d |  |  |  |  |
| 285 | 1.1.3.8.7 | SISTEMA DE RECEPCIÓN DE MANGUERA DE CISTERNA | 1d | 2007-06-21 | 2007-06-22 | 265 | 66.5d | 0d |  |  |  |  |
| 286 | 1.1.3.8.8 | PUERTA METÁLICA 0.30x0.20m PARA SIST. LLENADO DESDE CAMIÓN CISTERNA | 1d | 2007-06-22 | 2007-06-23 | 285 | 66.5d |  |  |  |  |  |
| 287 | 1.1.3.8.9 | PUERTA METÁLICA 0.20x0.20m P/VALVULA SIST. LLENADO DESDE CAMIÓN CISTERNA | 0.5d | 2007-06-22 | 2007-06-22 | 285 | 67d |  |  |  |  |  |
| 288 | 1.1.3.8.10 | CALENTADOR ELÉCTRICO DE 50L | 0.5d | 2007-07-22 | 2007-07-22 | 270, 226 | 37d |  |  |  |  |  |
| 289 | 1.1.3.8.11 | CALENTADOR ELÉCTRICO DE 80L | 1d | 2007-07-22 | 2007-07-23 | 270, 226 | 36.5d |  |  |  |  |  |
| 290 | 1.1.3.8.12 | EQUIPO DE BOMBEO: 2 ELECTROBOMBAS DE 0.5HP 220V 60HZ INCL. TABLERO | 1d | 2007-06-22 | 2007-06-23 | 284 | 66.5d |  |  |  |  |  |
| 291 | 1.1.3.8.13 | TANQUE ELEVADO DE POLIETILENO DE 2.50 m3 INC. ACCESORIOS | 1d | 2007-08-01 | 2007-08-02 | 274, 280 | 25.5d | 0d |  |  |  |  |
| 292 | 1.1.4 | **INSTALACIONES ELECTRICAS** | 103.5d | 2007-05-05 | 2007-08-16 |  | 12.5d |  |  | 2352.42h | 93,443.55 |  |
| 293 | 1.1.4.1 | **01.00 TOMACORRIENTES Y PUNTOS DE FUERZA** | 15d | 2007-06-15 | 2007-06-30 |  | 59.5d |  |  | 1723.44h | 49,059.11 |  |
| 294 | 1.1.4.1.1 | SALIDA TOMACORRIENTE BIPOLAR DOBLE C/TOMA TIERRA | 3d | 2007-06-15 | 2007-06-18 | 124SS+5d | 71.5d |  | CAPATAZ [1.12 H.H]; OPERARIO [11.18 H.H]; PEON [11.18 H.H]; CABLE TW 4 mm2 [1305.2 mL]; CAJA OCTOGONAL DE FoGo 100x50 [154 und]; PEGAMENTO PARA TUBERIA PVC [3.3 gln]; CINTA AISLANTE [16.5 rll]; TUBERIA PVC SAP (ELEC) 15 MM [628 mL]; CURVA PVC SAP P/INST. ELECT. DE 15MM [328 und]; CONECTOR PVC SAP (ELEC) 15MM [328 und]; CABLE TW 6 mm2 [12.3 mL]; CAJA DE FoGo DE 100x100x55 [2 und]; CAJA DE MADERA DE 200x100x100 mm [10 und]; TUBERIA PVC SAP (ELEC) 20 MM [6 mL]; CURVA PVC SAP P/INST. ELECT. DE 20MM [2 und]; CONECTOR PVC SAP (ELEC) 20MM [2 und]; HERRAMIENTAS MANUALES [157.42 x1.00] | 563.64h | 8,434.77 |  |
| 295 | 1.1.4.1.2 | SALIDA TOMACORRIENTES BIPOLARES SIMPLES C/TENSION ESTABILIZADA Y CON TOMA A TIERRA | 3d | 2007-06-15 | 2007-06-18 | 124SS+5d | 59.5d | 0d | CAPATAZ [0.1 H.H]; OPERARIO [1 H.H]; PEON [1 H.H]; CABLE TW 4 mm2 [592 mL]; PLACA DE ALUMINIO ANODIZADO DE 1 HUECO [65 und]; DADO INTERRUPTOR [75 und]; CAJA DE FoGo DE 100x55x50 [71 und]; PEGAMENTO PARA TUBERIA PVC [0.36 gln]; CINTA AISLANTE [7.1 rll]; TUBERIA PVC SAP (ELEC) 15 MM [213 mL]; CURVA PVC SAP P/INST. ELECT. DE 15MM [73 und]; CONECTOR PVC SAP (ELEC) 15MM [142 und]; PLACA DE ALUMINIO ANODIZADO DE 2 HUECOS [6 und]; HERRAMIENTAS MANUALES [41.64 x1.00]; DADO DE CONMUTACION [2 und] | 50.4h | 2,466.33 | 1,973.43 |
| 296 | 1.1.4.1.3 | SALIDA PARA ELECTROBOMBAS | 1d | 2007-06-18 | 2007-06-19 | 295 | 70d | 0d | CAPATAZ [1.61 H.H]; OPERARIO [16.06 H.H]; PEON [16.06 H.H]; CABLE TW 4 mm2 [1616 mL]; PLACA DE ACERO INOXIDABLE DE 2 HUECOS [100 und]; DADO TOMACORRIENTE BIPOLAR 15A / 220V [200 und]; CAJA DE FoGo DE 100x55x50 [116 und]; PEGAMENTO PARA TUBERIA PVC [0.66 gln]; CINTA AISLANTE [11.6 rll]; TUBERIA PVC SAP (ELEC) 20 MM [519 mL]; CURVA PVC SAP P/INST. ELECT. DE 20MM [232 und]; CONECTOR PVC SAP (ELEC) 20MM [232 und]; TOMACORRIENTE DOBLE A PRUEBA DE AGUA [16 und]; HERRAMIENTAS MANUALES [75.33 x1.00] | 269.81h | 8,729.54 |  |
| 297 | 1.1.4.1.4 | SALIDA A SENSOR DE NIVEL DE AGUA | 0.5d | 2007-06-19 | 2007-06-19 | 296 | 70d |  | CAPATAZ [0.1 H.H]; OPERARIO [1 H.H]; PEON [1 H.H]; CABLE TW 4 mm2 [231.1 mL]; CABLE THW 4mm2 [264 mL]; CAJA DE FoGo DE 100x100x55 [12 und]; INTERRUPTOR TERMOMAGNETICO 3X20A [11 und]; PEGAMENTO PARA TUBERIA PVC [0.17 gln]; CINTA AISLANTE [1.7 rll]; TUBERIA PVC SAP (ELEC) 20 MM [190.5 mL]; CURVA PVC SAP P/INST. ELECT. DE 20MM [38 und]; CONECTOR PVC SAP (ELEC) 20MM [38 und]; PLACA DE ALUMINIO ANODIZADO DE 2 HUECOS [2 und]; DADO TOMACORRIENTE C/TIERRA 15A / 220V [4 und]; ALAMBRE GALVANIZADO # 16 [0.31 kg]; PLACA DE ALUMINIO ANODIZADO DE 1 HUECO [5 und]; CAJA DE FoGo DE 100x55x50 [7 und]; CAJA OCTOGONAL DE FoGo 100x50 [1 und]; CABLE TW 10 mm2 [20.6 mL]; HERRAMIENTAS MANUALES [15.64 x1.00] | 8.4h | 2,305.06 |  |
| 298 | 1.1.4.1.5 | SALIDA UPS PARA CÓMPUTO | 2d | 2007-06-18 | 2007-06-20 | 295 | 59.5d | 0d | CAPATAZ [0.1 H.H]; OPERARIO [1 H.H]; PEON [1 H.H]; ALAMBRE GALVANIZADO # 16 [7.93 kg]; CAJA DE FoGo DE 100x100x55 [3 und]; PEGAMENTO PARA TUBERIA PVC [0.43 gln]; TUBERIA PVC SAP (ELEC) 20 MM [352 mL]; CURVA PVC SAP P/INST. ELECT. DE 20MM [56 und]; CONECTOR PVC SAP (ELEC) 20MM [56 und]; CAJA OCTOGONAL DE FoGo 100x55 [30 und]; UNION PVC SAP (ELEC) 20MM [37 und]; TAPA CIEGA DE PLASTICO [22 und]; CAJA DE MADERA DE 300x300x120 mm [5 und]; CAJA DE FoGo DE 100x55x50 [5 und]; PLACA DE ALUMINIO ANODIZADO DE 1 HUECO [4 und]; HERRAMIENTAS MANUALES [27.22 x1.00] | 33.6h | 1,766.62 |  |
| 299 | 1.1.4.1.6 | SALIDA PARA ENERGIZADOR DE CERCO ELÉCTRICO | 2d | 2007-06-20 | 2007-06-22 | 298 | 59.5d | 0d | CAPATAZ [2.06 H.H]; OPERARIO [20.59 H.H]; PEON [20.59 H.H]; PEGAMENTO PARA TUBERIA PVC [9.75 gln]; TUBERIA PVC SAP (ELEC) 20 MM [1042.5 mL]; CURVA PVC SAP P/INST. ELECT. DE 20MM [102 und]; UNION PVC SAP (ELEC) 20MM [337 und]; TUBERIA PVC SAP (ELEC) 25 MM [416 mL]; CURVA PVC SAP P/INST. ELECT. DE 25MM [41 und]; UNION PVC SAP (ELEC) 25MM [135 und]; TUBERIA PVC SAP (ELEC) 35 MM [176.5 mL]; CURVA PVC SAP P/INST. ELECT. DE 35MM [17 und]; UNION PVC SAP (ELEC) 35MM [57 und]; TUBERIA PVC SAP (ELEC) 50 MM [127.5 mL]; CURVA PVC SAP P/INST. ELECT. DE 50MM [13 und]; UNION PVC SAP (ELEC) 50MM [42 und]; TUBERIA PVC SAP (ELEC) 65 MM [64 mL]; CURVA PVC SAP P/INST. ELECT. DE 65MM [7 und]; UNION PVC SAP (ELEC) 65MM [21 und]; HERRAMIENTAS MANUALES [193.26 x1.00] | 691.99h | 16,165.69 |  |
| 300 | 1.1.4.1.7 | SALIDA DE FUERZA PARA CALENTADOR CON TIERRA | 2d | 2007-06-22 | 2007-06-24 | 299 | 59.5d | 0d | CAPATAZ [0.4 H.H]; OPERARIO [4 H.H]; PEON [2.2 H.H]; CABLE TW 2.5 mm2 [809.58 mL]; CABLE TW 4 mm2 [3130.17 mL]; CABLE TW 6 mm2 [14.94 mL]; CABLE TW 10 mm2 [44.81 mL]; CABLE THW 10mm2 [832.24 mL]; CABLE THW 25mm2 [339.9 mL]; CABLE THW 95mm2 [52.53 mL]; HERRAMIENTAS MANUALES [239.28 x1.00] | 105.6h | 9,191.1 |  |
| 301 | 1.1.4.1.8 | SALIDA PARA ESTERILIZADOR CON TIERRA | 2d | 2007-06-24 | 2007-06-26 | 300 | 59.5d | 0d |  |  |  |  |
| 302 | 1.1.4.1.9 | SALIDA PARA INTERRUPTOR TERMOMAG. LOCALIZADO | 2d | 2007-06-26 | 2007-06-28 | 301 | 59.5d | 0d |  |  |  |  |
| 303 | 1.1.4.1.10 | SALIDA PARA LUZ DE EMERGENCIA | 2d | 2007-06-28 | 2007-06-30 | 302 | 59.5d |  |  |  |  |  |

| ID | WBS | Task | Type | Duration | Start | Finish | Predecessors | Total slack | Free slack | Resources | Work | Cost | Baseline cost |
| --- | --- | --- | --- | --- | --- | --- | --- | --- | --- | --- | --- | --- | --- |
| 304 | 1.1.4.2 | **02.00 CENTROS DE LUZ** |  | 4d | 2007-07-13 | 2007-07-17 |  | 27.5d |  |  | 171.9h | 7,171.21 |  |
| 305 | 1.1.4.2.1 | SALIDA PARA CENTROS DE LUZ EN TECHO Y PARED EN EDIFICACION EXISTENTE |  | 4d | 2007-07-13 | 2007-07-17 | 84, 72 | 27.5d | 0d | CAPATAZ [0.1 H.H]; OPERARIO [1 H.H]; TABLERO GENERAL (SEGUN ESPECIFICACIONES) [1 und]; TABLERO TS-1 [1 und]; TABLERO TE-1 [1 und]; TABLERO TQ [1 und]; TABLERO TD-1 [1 und]; TABLERO TD-2 [1 und]; TABLERO TD-3 [1 und]; TABLERO TD-4 [1 und]; TABLERO STC [1 und]; HERRAMIENTAS MANUALES [240.2 x1.00]; PEON [0.9 H.H]; OFICIAL [0.3 H.H] | 73.6h | 2,225.61 |  |
| 306 | 1.1.4.2.2 | SALIDA PARA CENTROS DE LUZ EN TECHO Y PARED EN EDIFICACION PROYECTADA |  | 4d | 2007-07-13 | 2007-07-17 | 84, 72 | 37.5d | 0d | CAPATAZ [0.28 H.H]; OPERARIO [2.79 H.H]; INTERRUPTOR TERMOMAGNETICO 2X15A [17 und]; INTERRUPTOR TERMOMAGNETICO 2X20A [33 und]; INTERRUPTOR TERMOMAGNETICO 2X30A [1 und]; INTERRUPTOR TERMOMAGNETICO 3X30A [6 und]; INTERRUPTOR TERMOMAGNETICO 3X40A [3 und]; INTERRUPTOR TERMOMAGNETICO 3x75 A [4 und]; INTERRUPTOR TERMOMAGNETICO 3x90A [1 und]; INTERRUPTOR TERMOMAGNETICO 3X100A [1 und]; INTERRUPTOR TERMOMAGNETICO 3x175A [1 und]; HERRAMIENTAS MANUALES [30.22 x1.00] | 98.3h | 4,945.6 |  |
| 307 | 1.1.4.3 | **03.00 SALIDAS ESPECIALES** |  | 5d | 2007-07-17 | 2007-07-22 |  | 27.5d |  | CAPATAZ [0.1 H.H]; PEON [0.8 H.H]; ARENA GRUESA [0.81 m3]; AGUA [0.68 m3]; HERRAMIENTAS MANUALES [18.62 x1.00]; COMPACTADOR VIBRATORIO TIPO PLANCHA 4HP [0.2 HM.]; OPERARIO [0.2 H.H] | 457.09h | 37,213.24 |  |
| 308 | 1.1.4.3.1 | SALIDA PARA CENTRAL TELEFONICA |  | 1d | 2007-07-17 | 2007-07-18 | 305 | 27.5d | 0d | CAPATAZ [0.1 H.H]; OPERARIO [1 H.H]; PEON [1 H.H]; BUZON DE CONCRETO [5 und]; HERRAMIENTAS MANUALES [5.87 x1.00] | 16.8h | 762.27 |  |
| 309 | 1.1.4.3.2 | SALIDA PARA CENTRAL DE CÓMPUTO |  | 1d | 2007-07-17 | 2007-07-18 | 305 | 41.5d |  | CAPATAZ [0.1 H.H]; OPERARIO [1.1 H.H]; PEON [2.5 H.H]; OPERARIO ELECTRICISTA [200%]; TIERRA DE CHACRA [18.5 m3]; CABLE DE COBRE DESNUDO TIPO SUAVE 35mm2 [60 mL]; CONECTOR BR BARRA DE 5/8"-3/4" [6 und]; BARRA DE COBRE DE 3/4" x 2.40 m [5 und]; BENTONITA [15 pqt]; BARRA DE COBRE DE 5/8" x 2.40 m [3 und]; DOSIS QUIMICA THOR-GEL [6 und]; TAPA DE CONCRETO PARA POZO DE TIERRA [3 und]; CAPTOR THOR MOD. T-100 r=90m. [1 und]; SOPORTE P/TENSADO TIPO CARRETE FoGo [4 und]; MASTIL DE FoGo 2" y 3" C/ACOPLE P/PARARRAYO [1 und]; TUBO PROTECTOR DE FoGo 2"x3m C/ABRAZADERA [5 und]; TUBERIA PVC SAP (ELEC) 20 MM [45 mL]; HELICOIDAL DE 9m Cu 1/10 [3 und]; HERRAMIENTAS MANUALES [83.03 x1.00] | 45.6h | 8,010.51 |  |
| 310 | 1.1.4.3.3 | SALIDA PARA CENTRAL DE RADIO |  | 5d | 2007-07-17 | 2007-07-22 | 306 | 37.5d |  | CAPATAZ [0.48 H.H]; OPERARIO [4.84 H.H]; PEON [2.42 H.H]; ARTEF. TIPO A2 (ADOSADO C/DIFUSOR PRISMATICO) [52 und]; ARTEF. TIPO A4 (ADOSADO C/DIFUSOR PRISMATICO) [11 und]; ARTEF. TIPO A6 (ADOSADO C/DIFUSOR PRISMATICO) [11 und]; ARTEF. TIPO G1 DIF. TIPO GLOBO VID. 1X11W [30 und]; ARTEF. BRAQUETE DE ALUMINIO FLUORESECNTE COMPACTO [17 und]; ARTEF. TIPO D (ADOSADO) CUAD. 2´X2´ DIF.REJ.ALUM 2x36W AFP [18 und]; ARTEF. LUZ DE GUARDIA P/EMPOTRAR DIF. REJILLA CON LAMPAR [10 und]; LUZ DE EMERGENCIA [11 und]; ARTEFACTO TIPO ANTORCHA [20 und]; HERRAMIENTAS MANUALES [89.53 x1.00] | 309.89h | 27,304.92 |  |
| 311 | 1.1.4.3.4 | SALIDA PARA CENTRAL DE ALARMA CONTRAINCENDIO |  | 1d | 2007-07-18 | 2007-07-19 | 308 | 39.5d | 0d |  |  |  |  |
| 312 | 1.1.4.3.5 | SALIDA PARA CENTRAL DE MUSICA Y PERIFONEO |  | 1d | 2007-07-18 | 2007-07-19 | 308 | 40.5d |  | CAPATAZ [0.1 H.H]; OPERARIO [1 H.H]; PEON [1 H.H]; HERRAMIENTAS MANUALES [31.28 x1.00]; MEGOMETRO [2 HM.] | 32.8h | 247.68 | 4,359.99 |
| 313 | 1.1.4.3.6 | SALIDA SILLON DENTAL/COMPRESOR |  | 1d | 2007-07-19 | 2007-07-20 | 311 | 39.5d |  | MURETE PTA GAB ELECT 1.50x1.80x.25 [1 und] |  | 415 | 3,298.73 |
| 314 | 1.1.4.4 | **04.00 SALIDA PARA COMUNICACIONES Y SEÑALES** |  | 10d | 2007-07-22 | 2007-08-01 |  | 27.5d |  |  |  |  |  |
| 315 | 1.1.4.4.1 | SALIDA PARA TELEFONO | milestone | 0d | 2007-07-22 | 2007-07-22 | 308FS+4d | 27.5d | 0d |  |  |  |  |
| 316 | 1.1.4.4.2 | SALIDA PARA INTERCOMUNICADOR |  | 1d | 2007-07-22 | 2007-07-23 | 315 | 27.5d | 0d |  |  |  |  |
| 317 | 1.1.4.4.3 | SALIDA PARA RED DE CÓMPUTO |  | 1d | 2007-07-23 | 2007-07-24 | 316 | 27.5d | 0d |  |  |  |  |
| 318 | 1.1.4.4.4 | SALIDA PARA TV CABLE |  | 1d | 2007-07-24 | 2007-07-25 | 317 | 27.5d | 0d |  |  |  |  |
| 319 | 1.1.4.4.5 | SALIDA PARA PARLANTE |  | 1d | 2007-07-25 | 2007-07-26 | 318 | 27.5d | 0d |  |  |  |  |
| 320 | 1.1.4.4.6 | SALIDA PARA DETECTOR DE HUMO |  | 1d | 2007-07-26 | 2007-07-27 | 319 | 27.5d | 0d |  |  |  |  |
| 321 | 1.1.4.4.7 | SALIDA PARA SENSOR DE TEMPERATURA |  | 1d | 2007-07-27 | 2007-07-28 | 320 | 27.5d | 0d |  |  |  |  |
| 322 | 1.1.4.4.8 | SALIDA PARA ESTACION MANUAL DE ALARMA CONTRAINCENDIO |  | 1d | 2007-07-28 | 2007-07-29 | 321 | 27.5d | 0d |  |  |  |  |
| 323 | 1.1.4.4.9 | SALIDA PARA ALARMA CONTRAROBOS |  | 1d | 2007-07-29 | 2007-07-30 | 322 | 27.5d | 0d |  |  |  |  |
| 324 | 1.1.4.4.10 | SALIDA PARA ANTENA DE RADIO ALTA FRECUENCIA |  | 1d | 2007-07-30 | 2007-07-31 | 323 | 27.5d | 0d |  |  |  |  |
| 325 | 1.1.4.4.11 | SALIDA PARA EXTRACTOR AXIAL |  | 1d | 2007-07-31 | 2007-08-01 | 324 | 27.5d |  |  |  |  |  |
| 326 | 1.1.4.5 | **05.00 TUBERIAS PVC** |  | 3d | 2007-06-13 | 2007-06-16 |  | 45.5d |  |  |  |  |  |
| 327 | 1.1.4.5.1 | TUBERIAS PVC SAP D=15MM |  | 3d | 2007-06-13 | 2007-06-16 | 84 | 45.5d | 0d |  |  |  |  |
| 328 | 1.1.4.5.2 | TUBERIAS PVC SAP (ELECTRICAS) D=25MM |  | 3d | 2007-06-13 | 2007-06-16 | 84 | 72.5d | 14d |  |  |  |  |
| 329 | 1.1.4.5.3 | TUBERIAS PVC SAP (ELECTRICAS) D=35MM |  | 3d | 2007-06-13 | 2007-06-16 | 84 | 72.5d | 14d |  |  |  |  |

| ID | WBS | Task | Duration | Start | Finish | Predecessors | Total slack | Free slack |
| --- | --- | --- | --- | --- | --- | --- | --- | --- |
| 330 | 1.1.4.6 | **06.00 CONDUCTORES Y CABLES** | 7d | 2007-06-23 | 2007-06-30 |  | 45.5d |  |
| 331 | 1.1.4.6.1 | CABLE PARA DATA UTP MULTIFILAR | 1d | 2007-06-23 | 2007-06-24 | 327FS+7d | 45.5d | 0d |
| 332 | 1.1.4.6.2 | CONDUCTORES TW 6.0mm2 | 1d | 2007-06-24 | 2007-06-25 | 331 | 45.5d | 0d |
| 333 | 1.1.4.6.3 | CONDUCTORES LT.: TW 10mm2 | 1d | 2007-06-25 | 2007-06-26 | 332 | 45.5d | 0d |
| 334 | 1.1.4.6.4 | CONDUCTORES THW 2-1x6mm2 | 1d | 2007-06-26 | 2007-06-27 | 333 | 45.5d | 0d |
| 335 | 1.1.4.6.5 | CONDUCTORES THW 3-1x16mm2 | 1d | 2007-06-27 | 2007-06-28 | 334 | 45.5d | 0d |
| 336 | 1.1.4.6.6 | CONDUCTOR TW: 2-1x4mm2 + 1x4mm2/T | 1d | 2007-06-28 | 2007-06-29 | 335 | 45.5d | 0d |
| 337 | 1.1.4.6.7 | CONDUCTOR TW: 2-1x2.5mm2 + 1x2.5 mm2/T | 1d | 2007-06-29 | 2007-06-30 | 336 | 45.5d | 0d |
| 338 | 1.1.4.7 | **07.00 CAJAS DE PASE** | 1d | 2007-06-30 | 2007-07-01 | 337 | 45.5d |  |
| 339 | 1.1.4.7.1 | CAJA DE PASO OCTOGONAL DE 100x40mm | 1d | 2007-06-30 | 2007-07-01 | 84 | 45.5d | 0d |
| 340 | 1.1.4.7.2 | CAJA CUADRADA 100X100X50 mm | 1d | 2007-06-30 | 2007-07-01 | 84 | 58.5d |  |
| 341 | 1.1.4.7.3 | CAJA CUADRADA 150X150X100 mm | 1d | 2007-06-30 | 2007-07-01 | 84 | 58.5d |  |
| 342 | 1.1.4.7.4 | CAJA CUADRADA 200X200X100 mm | 1d | 2007-06-30 | 2007-07-01 | 84 | 58.5d |  |
| 343 | 1.1.4.7.5 | CAJA CUADRADA 300X300X200 mm | 1d | 2007-06-30 | 2007-07-01 | 328 | 58.5d |  |
| 344 | 1.1.4.7.6 | CAJA CUADRADA 250X250X200 mm | 1d | 2007-06-30 | 2007-07-01 | 329 | 58.5d |  |
| 345 | 1.1.4.8 | **08.00 TABLEROS DE DISTRIBUCION** | 6d | 2007-07-01 | 2007-07-07 |  | 45.5d |  |
| 346 | 1.1.4.8.1 | TABLERO GENERAL TG- 48 P, 3 ø, SEGUN DISEÑO | 1d | 2007-07-01 | 2007-07-02 | 339 | 45.5d | 0d |
| 347 | 1.1.4.8.2 | TABLERO TTE, 36P, 1ø, SEGUN DISEÑO | 1d | 2007-07-02 | 2007-07-03 | 346 | 52.5d | 0d |
| 348 | 1.1.4.8.3 | TABLERO TA-2, 28P, 3ø, SEGUN DETALLE | 1d | 2007-07-03 | 2007-07-04 | 347 | 52.5d | 0d |
| 349 | 1.1.4.8.4 | TABLERO TA-3, 28P, 3ø, SEGUN DISEÑO | 1d | 2007-07-04 | 2007-07-05 | 348 | 52.5d | 0d |
| 350 | 1.1.4.8.5 | TABLERO ALTERNADOR TB, P/2 ELECT. 1/2 HP | 1d | 2007-07-05 | 2007-07-06 | 349 | 52.5d | 0d |
| 351 | 1.1.4.8.6 | TABLERO TCM CONTROL Y MANDO DEL GENERADOR | 1d | 2007-07-06 | 2007-07-07 | 350 | 52.5d |  |
| 352 | 1.1.4.9 | **09.00 REDES EXTERIORES Y MEDIDORES** | 1d | 2007-05-05 | 2007-05-05 |  | 115d |  |
| 353 | 1.1.4.9.1 | DESMONTAJE DE REDES EXISTENTES | 1d | 2007-05-05 | 2007-05-05 | 22 | 115d |  |

| ID | WBS | Task | Type | Duration | Start | Finish | Predecessors | Total slack | Free slack |
| --- | --- | --- | --- | --- | --- | --- | --- | --- | --- |
| 354 | 1.1.4.10 | **10.00 SISTEMA PUESTA A TIERRA** |  | 1d | 2007-08-01 | 2007-08-02 |  | 12.5d |  |
| 355 | 1.1.4.10.1 | POZO CONEXION A TIERRA R<15 OHMIOS |  | 1d | 2007-08-01 | 2007-08-02 | 363 | 12.5d | 0d |
| 356 | 1.1.4.10.2 | POZO CONEXION A TIERRA R<5 OHMIOS |  | 1d | 2007-08-01 | 2007-08-02 | 363 | 26.5d |  |
| 357 | 1.1.4.11 | **11.00 ARTEFACTOS DE ALUMBRADO** |  | 14d | 2007-07-27 | 2007-08-10 |  | 12.5d |  |
| 358 | 1.1.4.11.1 | ARTEFACTO FLUORESCENTE TIPO B1 1 X 40W, ADOSADO, EQUIPO COMPLETO | milestone | 0d | 2007-08-10 | 2007-08-10 | 226, 347, 365 | 18.5d |  |
| 359 | 1.1.4.11.2 | ARTEFACTO FLUORESCENTE TIPO B2 2 X 40 W, ADOSADO, EQUIPO COMPLETO |  | 1d | 2007-07-27 | 2007-07-28 | 226FS+5d | 12.5d | 0d |
| 360 | 1.1.4.11.3 | ARTEFACTO FLUORESCENTE TIPO F-1 1 X 40 W, ADOSADO EQUIPO COMPLETO |  | 1d | 2007-07-28 | 2007-07-29 | 359 | 12.5d | 0d |
| 361 | 1.1.4.11.4 | ARTEFACTO FLUORESCENTE TIPO CIRCULAR 1 X 32W, ADOSADO EQUIPO COMPLETO |  | 1d | 2007-07-29 | 2007-07-30 | 360 | 12.5d | 0d |
| 362 | 1.1.4.11.5 | ARTEFACTO G1 6x3 PORTAGLOBO DE VIDRIO INCLUYE EQUIPO Y PANTALLA |  | 1d | 2007-07-30 | 2007-07-31 | 361 | 12.5d | 0d |
| 363 | 1.1.4.11.6 | ARTEFACTO PARA LUZ DE EMERGENCIA |  | 1d | 2007-07-31 | 2007-08-01 | 362 | 12.5d | 0d |
| 364 | 1.1.4.12 | **12.0 VARIOS** |  | 7d | 2007-08-09 | 2007-08-16 |  | 12.5d |  |
| 365 | 1.1.4.12.1 | GENERADOR ELECTRICO 5 KW 220V 60HZ |  | 1d | 2007-08-09 | 2007-08-10 | 346FS+5d, 355FS+7d, 363FS+8d | 12.5d | 0d |
| 366 | 1.1.4.12.2 | EQUIPO DE PERIFONEO |  | 1d | 2007-08-10 | 2007-08-11 | 365 | 12.5d | 0d |
| 367 | 1.1.4.12.3 | PARLANTES EN FORMA ANGULAR DE 8" |  | 1d | 2007-08-11 | 2007-08-12 | 366 | 15.5d | 0d |
| 368 | 1.1.4.12.4 | UPS 1.5 KVA 220VAC/60Hz |  | 1d | 2007-08-12 | 2007-08-13 | 367 | 15.5d |  |
| 369 | 1.1.4.12.5 | EXTRACTOR AXIAL |  | 1d | 2007-08-12 | 2007-08-13 | 367 | 15.5d |  |
| 370 | 1.1.4.12.6 | DETECTOR DE HUMO |  | 1d | 2007-08-12 | 2007-08-13 | 367 | 15.5d |  |
| 371 | 1.1.4.12.7 | SENSOR DE TEMPERATURA |  | 1d | 2007-08-11 | 2007-08-12 | 366 | 16.5d |  |
| 372 | 1.1.4.12.8 | ESTACIÓN DE ALARMA CONTRAINCENDIO |  | 1d | 2007-08-11 | 2007-08-12 | 366 | 12.5d | 0d |
| 373 | 1.1.4.12.9 | SIRENA DE LARGO ALCANCE C/ROBO |  | 1d | 2007-08-12 | 2007-08-13 | 372 | 12.5d | 0d |
| 374 | 1.1.4.12.10 | CERCO ELÉCTRICO |  | 1d | 2007-08-13 | 2007-08-14 | 373 | 12.5d | 0d |
| 375 | 1.1.4.12.11 | PRUEBAS ELECTRICAS |  | 2d | 2007-08-14 | 2007-08-16 | 374, 365 | 12.5d |  |
